# نیروگاه خورشیدی یزد- پترو کاویان صنعت پارس

Schedule from MS Project, 2026-01-11 to 2026-09-12, costs in IRR.

## Calendars

- Standard: Mon-Sun 08:00-12:00, 13:00-17:00. Exceptions (off unless hours are given): 2026-03-20 to 2026-03-24 (عید نوروز).

## Schedule

| ID | WBS | Task | Type | Duration | Start | Finish | Predecessors | Baseline start | Baseline finish | Baseline duration | Total slack | Free slack | Cost | start shamsi | finish shamsi |
| --- | --- | --- | --- | --- | --- | --- | --- | --- | --- | --- | --- | --- | --- | --- | --- |
| 1 | 1 | شروع | milestone | 0d | 2026-01-11 | 2026-01-11 |  | 2026-01-11 | 2026-01-11 | 0d | 0d |  |  | 1404/10/21 | 1404/10/21 |
| 2 | 2 | **مایلستون های کلیدی** |  | 228d | 2026-01-13 | 2026-09-03 |  | 2026-01-13 | 2026-09-04 | 229d | 1d |  |  | 1404/10/23 | 1405/6/12 |
| 3 | 2.1 | دریافت سایر اطلاعات مقدماتی از کارفرما (آزمایش شیمیایی خاک، تست کشش پایه ها و…) | milestone | 0d | 2026-01-13 | 2026-01-13 | 1FS+3d | 2026-01-13 | 2026-01-13 | 0d | 1d | 0d |  | 1404/10/23 | 1404/10/23 |
| 4 | 2.2 | واریز اولین پیش پرداخت بخش مهندسی | milestone | 0d | 2026-02-02 | 2026-02-02 | 1FS+23d | 2026-02-02 | 2026-02-02 | 0d | 0d |  |  | 1404/11/13 | 1404/11/13 |
| 5 | 2.3 | دریافت مطالعات ژئوتکنیک | milestone | 0d | 2026-01-13 | 2026-01-13 | 3 | 2026-01-13 | 2026-01-13 | 0d | 20d | 14d |  | 1404/10/23 | 1404/10/23 |
| 6 | 2.4 | تحویل زمین | milestone | 0d | 2026-01-26 | 2026-01-26 | 1FS+16d | 2026-01-26 | 2026-01-26 | 0d | 0d |  |  | 1404/11/6 | 1404/11/6 |
| 7 | 2.5 | تاییدیه تجهیزات (پنل، اینورتر و MVStation( | milestone | 0d | 2026-01-22 | 2026-01-22 | 25FS-6d, 26FS-6d, 27FS-6d | 2026-01-22 | 2026-01-22 | 0d | 5d |  |  | 1404/11/2 | 1404/11/2 |
| 8 | 2.6 | اتمام طراحی و اخذ تاییدیه | milestone | 0d | 2026-03-08 | 2026-03-08 | 68, 69, 70, 71, 73, 74, 75, 76, 77, 78, 80, 81, 93, 83, 84, 85, 86, 87, 88, 89, 90, 91, 94, 96, 97, 98, 99, 111, 113, 114, 123, 124, 116, 118, 119, 121, 122, 126, 128, 129, 130, 132, 133, 134, 135, 136, 137, 138, 142, 143, 160, 162, 163, 164, 169, 170, 171, 175, 176, 177, 178, 180, 181, 179, 25, 28, 29, 30, 31, 32, 33, 34, 35, 36, 37, 156, 38, 39, 168, 112, 149 | 2026-03-08 | 2026-03-08 | 0d | 0d |  |  | 1404/12/17 | 1404/12/17 |
| 9 | 2.7 | اتمام استعلام قیمتی و سفارش گذاری خرید خارجی | milestone | 0d | 2026-02-27 | 2026-02-27 | 266, 272, 278, 284 | 2026-02-27 | 2026-02-27 | 0d | 13d | 0d |  | 1404/12/8 | 1404/12/8 |
| 10 | 2.8 | اتمام تامین و تحویل خرید خارجی در سایت پروژه | milestone | 0d | 2026-07-21 | 2026-07-21 | 270, 276, 282, 288 | 2026-07-21 | 2026-07-21 | 0d | 17d | 0d |  | 1405/4/30 | 1405/4/30 |
| 11 | 2.9 | اتمام تجهیز کارگاه | milestone | 0d | 2026-03-08 | 2026-03-08 | 291, 292, 293 | 2026-03-09 | 2026-03-09 | 0d | 0d |  |  | 1404/12/17 | 1404/12/17 |
| 12 | 2.10 | اتمام نصب سازه | milestone | 0d | 2026-07-19 | 2026-07-19 | 338 | 2026-07-19 | 2026-07-19 | 0d | 43d | 33d |  | 1405/4/28 | 1405/4/28 |
| 13 | 2.11 | اتمام نصب پنل | milestone | 0d | 2026-08-21 | 2026-08-21 | 339 | 2026-08-21 | 2026-08-21 | 0d | 10d |  |  | 1405/5/30 | 1405/5/30 |
| 14 | 2.12 | اتمام ساختمان مانیتورینگ | milestone | 0d | 2026-09-03 | 2026-09-03 | 323 | 2026-09-04 | 2026-09-04 | 0d | 0d |  |  | 1405/6/12 | 1405/6/12 |
| 15 | 2.13 | اتمام نصب MVStaion | milestone | 0d | 2026-07-23 | 2026-07-23 | 351 | 2026-07-23 | 2026-07-23 | 0d | 44d | 42d |  | 1405/5/1 | 1405/5/1 |
| 16 | 2.14 | اتمام نصب اینورتر | milestone | 0d | 2026-07-29 | 2026-07-29 | 342 | 2026-07-29 | 2026-07-29 | 0d | 17d | 0d |  | 1405/5/7 | 1405/5/7 |
| 17 | 2.15 | تست پست بالادست | milestone | 0d | 2026-07-12 | 2026-07-12 | 412 | 2026-07-12 | 2026-07-12 | 0d | 58d |  |  | 1405/4/21 | 1405/4/21 |
| 18 | 3 | **مهندسی** |  | 128d | 2026-01-14 | 2026-05-26 |  | 2026-01-14 | 2026-05-26 | 128d | 1d |  | 28,160,614,893.04 | 1404/10/24 | 1405/3/5 |
| 19 | 3.1 | **مدیریت پروژه** |  | 30d | 2026-01-14 | 2026-02-12 |  |  |  |  | 17d |  | 2,252,849,191.68 | 1404/10/24 | 1404/11/23 |
| 20 | 3.1.1 | Master Document List |  | 10d | 2026-01-14 | 2026-01-23 | 3 |  |  |  | 17d | 0d | 606,536,320.84 | 1404/10/24 | 1404/11/3 |
| 21 | 3.1.2 | Time Schedule |  | 10d | 2026-01-24 | 2026-02-02 | 20 |  |  |  | 17d | 0d | 996,452,527.09 | 1404/11/4 | 1404/11/13 |
| 22 | 3.1.3 | Cash Flow |  | 10d | 2026-02-03 | 2026-02-12 | 21 |  |  |  | 207d |  | 649,860,343.75 | 1404/11/14 | 1404/11/23 |
| 23 | 3.2 | **طراحی و اخذ تاییدیه طراحی پایه** |  | 27d | 2026-01-14 | 2026-02-09 |  | 2026-01-14 | 2026-02-09 | 27d | 1d |  | 4,355,854,292.03 | 1404/10/24 | 1404/11/20 |
| 24 | 3.2.1 | **ارایه و اخذ تاییدیه دیتاشیت ها** |  | 23d | 2026-01-18 | 2026-02-09 |  | 2026-01-18 | 2026-02-09 | 23d | 1d |  | 418,828,828.43 | 1404/10/28 | 1404/11/20 |
| 25 | 3.2.1.1 | Solar Panel Datasheet |  | 10d | 2026-01-18 | 2026-01-27 | 47FS-6d | 2026-01-18 | 2026-01-27 | 10d | 1d | 0d | 231,282,221.35 | 1404/10/28 | 1404/11/7 |
| 26 | 3.2.1.2 | Inverter Datasheet |  | 10d | 2026-01-18 | 2026-01-27 | 48FS-6d | 2026-01-18 | 2026-01-27 | 10d | 1d | 0d | 3,136,716.44 | 1404/10/28 | 1404/11/7 |
| 27 | 3.2.1.3 | MV Station Datasheet |  | 10d | 2026-01-18 | 2026-01-27 | 49FS-6d | 2026-01-18 | 2026-01-27 | 10d | 1d | 0d | 3,136,716.44 | 1404/10/28 | 1404/11/7 |
| 28 | 3.2.1.4 | DC Connection (MC4) Datasheet |  | 10d | 2026-01-18 | 2026-01-27 | 50FS-6d | 2026-01-18 | 2026-01-27 | 10d | 1d | 0d | 24,185,734.78 | 1404/10/28 | 1404/11/7 |
| 29 | 3.2.1.5 | DC Cable Datasheet |  | 10d | 2026-01-18 | 2026-01-27 | 51FS-6d | 2026-01-18 | 2026-01-27 | 10d | 1d | 0d | 19,103,310.77 | 1404/10/28 | 1404/11/7 |
| 30 | 3.2.1.6 | LV Cable Datasheet |  | 10d | 2026-01-18 | 2026-01-27 | 52FS-6d | 2026-01-18 | 2026-01-27 | 10d | 1d | 0d | 32,959,107.14 | 1404/10/28 | 1404/11/7 |
| 31 | 3.2.1.7 | MV Cable Datasheet |  | 10d | 2026-01-18 | 2026-01-27 | 53FS-6d | 2026-01-18 | 2026-01-27 | 10d | 1d | 0d | 20,187,677.39 | 1404/10/28 | 1404/11/7 |
| 32 | 3.2.1.8 | MV Switchgear (CT, PT, Relay) Datasheet |  | 10d | 2026-01-18 | 2026-01-27 | 54FS-6d | 2026-01-18 | 2026-01-27 | 10d | 1d | 0d | 2,228,719.58 | 1404/10/28 | 1404/11/7 |
| 33 | 3.2.1.9 | Earthing and Lightning Datasheet |  | 10d | 2026-01-18 | 2026-01-27 | 55FS-6d | 2026-01-18 | 2026-01-27 | 10d | 1d | 0d | 32,675,807.52 | 1404/10/28 | 1404/11/7 |
| 34 | 3.2.1.10 | Auxiliary Transformer Datasheet |  | 10d | 2026-01-18 | 2026-01-27 | 56FS-6d | 2026-01-18 | 2026-01-27 | 10d | 1d | 0d | 6,516,723.95 | 1404/10/28 | 1404/11/7 |
| 35 | 3.2.1.11 | UPS and Battery Datasheet |  | 10d | 2026-01-18 | 2026-01-27 | 57FS-6d | 2026-01-18 | 2026-01-27 | 10d | 1d | 0d | 2,944,446.59 | 1404/10/28 | 1404/11/7 |
| 36 | 3.2.1.12 | Diesel Generator Datasheet |  | 10d | 2026-01-18 | 2026-01-27 | 58FS-6d | 2026-01-18 | 2026-01-27 | 10d | 1d | 0d | 2,814,039.88 | 1404/10/28 | 1404/11/7 |
| 37 | 3.2.1.13 | Monitoring System Datasheet |  | 10d | 2026-01-18 | 2026-01-27 | 59FS-6d | 2026-01-18 | 2026-01-27 | 10d | 1d | 0d | 10,331,353.43 | 1404/10/28 | 1404/11/7 |
| 38 | 3.2.1.14 | Data Logger Datasheet |  | 10d | 2026-01-31 | 2026-02-09 | 60FS-6d | 2026-01-31 | 2026-02-09 | 10d | 27d |  |  | 1404/11/11 | 1404/11/20 |
| 39 | 3.2.1.15 | Weather Station Datasheet |  | 10d | 2026-01-31 | 2026-02-09 | 61FS-6d | 2026-01-31 | 2026-02-09 | 10d | 27d |  |  | 1404/11/11 | 1404/11/20 |
| 40 | 3.2.1.16 | CCTV and NVR Datasheet |  | 10d | 2026-01-31 | 2026-02-09 | 62FS-6d | 2026-01-31 | 2026-02-09 | 10d | 13d | 8d | 21,181,895.91 | 1404/11/11 | 1404/11/20 |
| 41 | 3.2.1.17 | HVAC Datasheet |  | 10d | 2026-01-31 | 2026-02-09 | 63FS-6d | 2026-01-31 | 2026-02-09 | 10d | 0d |  | 3,120,207.41 | 1404/11/11 | 1404/11/20 |
| 42 | 3.2.1.18 | Piping Material, Plumbing Fittings, Pumps Datasheet |  | 10d | 2026-01-31 | 2026-02-09 | 64FS-6d | 2026-01-31 | 2026-02-09 | 10d | 0d |  | 808,343.9 | 1404/11/11 | 1404/11/20 |
| 43 | 3.2.1.19 | Septic Tank Datasheet |  | 10d | 2026-01-31 | 2026-02-09 | 65FS-6d | 2026-01-31 | 2026-02-09 | 10d | 0d |  | 808,343.9 | 1404/11/11 | 1404/11/20 |
| 44 | 3.2.1.20 | Water TankDatasheet |  | 10d | 2026-01-31 | 2026-02-09 | 66FS-6d | 2026-01-31 | 2026-02-09 | 10d | 0d |  | 808,343.9 | 1404/11/11 | 1404/11/20 |
| 45 | 3.2.1.21 | Fire Alarm System Datasheet |  | 10d | 2026-01-31 | 2026-02-09 | 67FS-6d | 2026-01-31 | 2026-02-09 | 10d | 17d | 15d | 599,118.15 | 1404/11/11 | 1404/11/20 |

| ID | WBS | Task | Duration | Start | Finish | Predecessors | Baseline start | Baseline finish | Baseline duration | Total slack | Free slack | Cost | start shamsi | finish shamsi |
| --- | --- | --- | --- | --- | --- | --- | --- | --- | --- | --- | --- | --- | --- | --- |
| 46 | 3.2.2 | **ارایه و اخذ تاییدیه مشخصات** | 23d | 2026-01-14 | 2026-02-05 |  | 2026-01-14 | 2026-02-05 | 23d | 1d |  | 427,779,607.32 | 1404/10/24 | 1404/11/16 |
| 47 | 3.2.2.1 | Solar Panel Technical Specification | 10d | 2026-01-14 | 2026-01-23 | 3 | 2026-01-14 | 2026-01-23 | 10d | 1d | 0d | 231,282,221.35 | 1404/10/24 | 1404/11/3 |
| 48 | 3.2.2.2 | Inverter Technical Specification | 10d | 2026-01-14 | 2026-01-23 | 3 | 2026-01-14 | 2026-01-23 | 10d | 1d | 0d | 3,136,716.44 | 1404/10/24 | 1404/11/3 |
| 49 | 3.2.2.3 | MV Station Technical Specification | 10d | 2026-01-14 | 2026-01-23 | 3 | 2026-01-14 | 2026-01-23 | 10d | 1d | 0d | 3,136,716.44 | 1404/10/24 | 1404/11/3 |
| 50 | 3.2.2.4 | DC Connection (MC4) Technical Specification | 10d | 2026-01-14 | 2026-01-23 | 3 | 2026-01-14 | 2026-01-23 | 10d | 1d | 0d | 24,185,734.78 | 1404/10/24 | 1404/11/3 |
| 51 | 3.2.2.5 | DC Cable Technical Specification | 10d | 2026-01-14 | 2026-01-23 | 3 | 2026-01-14 | 2026-01-23 | 10d | 1d | 0d | 19,103,310.77 | 1404/10/24 | 1404/11/3 |
| 52 | 3.2.2.6 | LV Cable Technical Specification | 10d | 2026-01-14 | 2026-01-23 | 3 | 2026-01-14 | 2026-01-23 | 10d | 1d | 0d | 32,959,107.14 | 1404/10/24 | 1404/11/3 |
| 53 | 3.2.2.7 | MV Cable Technical Specification | 10d | 2026-01-14 | 2026-01-23 | 3 | 2026-01-14 | 2026-01-23 | 10d | 1d | 0d | 20,187,677.39 | 1404/10/24 | 1404/11/3 |
| 54 | 3.2.2.8 | MV Switchgear (CT, PT, Relay) Technical Specification | 10d | 2026-01-14 | 2026-01-23 | 3 | 2026-01-14 | 2026-01-23 | 10d | 1d | 0d | 2,228,719.58 | 1404/10/24 | 1404/11/3 |
| 55 | 3.2.2.9 | Earthing and Lightning Technical Specification | 10d | 2026-01-14 | 2026-01-23 | 3 | 2026-01-14 | 2026-01-23 | 10d | 1d | 0d | 32,675,807.52 | 1404/10/24 | 1404/11/3 |
| 56 | 3.2.2.10 | Auxiliary Transformer Technical Specification | 10d | 2026-01-14 | 2026-01-23 | 3 | 2026-01-14 | 2026-01-23 | 10d | 1d | 0d | 6,516,723.95 | 1404/10/24 | 1404/11/3 |
| 57 | 3.2.2.11 | UPS and Battery Technical Specification | 10d | 2026-01-14 | 2026-01-23 | 3 | 2026-01-14 | 2026-01-23 | 10d | 1d | 0d | 2,944,446.59 | 1404/10/24 | 1404/11/3 |
| 58 | 3.2.2.12 | Diesel Generator Technical Specification | 10d | 2026-01-14 | 2026-01-23 | 3 | 2026-01-14 | 2026-01-23 | 10d | 1d | 0d | 7,035,099.7 | 1404/10/24 | 1404/11/3 |
| 59 | 3.2.2.13 | Monitoring System Technical Specification | 10d | 2026-01-14 | 2026-01-23 | 3 | 2026-01-14 | 2026-01-23 | 10d | 1d | 0d | 11,807,261.07 | 1404/10/24 | 1404/11/3 |
| 60 | 3.2.2.14 | Data Logger Technical Specification | 10d | 2026-01-27 | 2026-02-05 | 3, 6, 7 | 2026-01-27 | 2026-02-05 | 10d | 27d | 0d |  | 1404/11/7 | 1404/11/16 |
| 61 | 3.2.2.15 | Weather Station Technical Specification | 10d | 2026-01-27 | 2026-02-05 | 3, 6, 7 | 2026-01-27 | 2026-02-05 | 10d | 27d | 0d |  | 1404/11/7 | 1404/11/16 |
| 62 | 3.2.2.16 | CCTV and NVR Technical Specification | 10d | 2026-01-27 | 2026-02-05 | 3, 6, 7 | 2026-01-27 | 2026-02-05 | 10d | 13d | 0d | 24,207,881.04 | 1404/11/7 | 1404/11/16 |
| 63 | 3.2.2.17 | HVAC Technical Specification | 10d | 2026-01-27 | 2026-02-05 | 3, 6, 7 | 2026-01-27 | 2026-02-05 | 10d | 0d |  | 3,565,951.33 | 1404/11/7 | 1404/11/16 |
| 64 | 3.2.2.18 | Piping Material, Plumbing Fittings, Pumps Technical Specification | 10d | 2026-01-27 | 2026-02-05 | 3, 6, 7 | 2026-01-27 | 2026-02-05 | 10d | 0d |  | 923,821.6 | 1404/11/7 | 1404/11/16 |
| 65 | 3.2.2.19 | Septic Tank Technical Specification | 10d | 2026-01-27 | 2026-02-05 | 3, 6, 7 | 2026-01-27 | 2026-02-05 | 10d | 0d |  | 461,910.8 | 1404/11/7 | 1404/11/16 |
| 66 | 3.2.2.20 | Water Tank Technical Specification | 10d | 2026-01-27 | 2026-02-05 | 3, 6, 7 | 2026-01-27 | 2026-02-05 | 10d | 0d |  | 461,910.8 | 1404/11/7 | 1404/11/16 |
| 67 | 3.2.2.21 | Fire Alarm System Technical Specification | 10d | 2026-01-27 | 2026-02-05 | 3, 6, 7 | 2026-01-27 | 2026-02-05 | 10d | 17d | 0d | 958,589.03 | 1404/11/7 | 1404/11/16 |
| 68 | 3.2.3 | PVSYST Report | 10d | 2026-01-22 | 2026-01-31 | 25FS-6d, 26FS-6d, 27FS-6d, 28FS-6d, 29FS-6d, 30FS-6d, 31FS-6d, 37FS-6d, 36FS-6d, 35FS-6d, 34FS-6d, 33FS-6d, 32FS-6d | 2026-01-22 | 2026-01-31 | 10d | 1d | 0d | 779,832,412.5 | 1404/11/2 | 1404/11/11 |
| 69 | 3.2.4 | General Layout | 9d | 2026-01-22 | 2026-01-30 | 68SS | 2026-01-22 | 2026-01-30 | 9d | 1d | 0d | 909,804,481.26 | 1404/11/2 | 1404/11/10 |
| 70 | 3.2.5 | General Single Line Diagram (GSLD) | 10d | 2026-01-25 | 2026-02-03 | 69FS-6d | 2026-01-25 | 2026-02-03 | 10d | 5d | 0d | 909,804,481.26 | 1404/11/5 | 1404/11/14 |
| 71 | 3.2.6 | Plant Detailed Report | 10d | 2026-01-26 | 2026-02-04 | 68FS-6d | 2026-01-26 | 2026-02-04 | 10d | 7d | 0d | 909,804,481.26 | 1404/11/6 | 1404/11/15 |

| ID | WBS | Task | Duration | Start | Finish | Predecessors | Baseline start | Baseline finish | Baseline duration | Total slack | Free slack | Cost | start shamsi | finish shamsi |
| --- | --- | --- | --- | --- | --- | --- | --- | --- | --- | --- | --- | --- | --- | --- |
| 72 | 3.3 | **طراحی و اخذ تاییدیه عمرانی مطابق MDL ارایه شده** | 39d | 2026-01-28 | 2026-03-07 |  | 2026-01-28 | 2026-03-07 | 39d | 4d |  | 10,699,416,889.15 | 1404/11/8 | 1404/12/16 |
| 73 | 3.3.1 | Topography of Field | 10d | 2026-02-03 | 2026-02-12 | 3, 6, 4 | 2026-02-03 | 2026-02-12 | 10d | 5d | 0d | 3,698,023.59 | 1404/11/14 | 1404/11/23 |
| 74 | 3.3.2 | Geotechnical Test Report | 10d | 2026-02-03 | 2026-02-12 | 3, 4 | 2026-02-03 | 2026-02-12 | 10d | 10d | 0d | 3,698,023.59 | 1404/11/14 | 1404/11/23 |
| 75 | 3.3.3 | Ramming and Pull-Out Test Report | 10d | 2026-02-03 | 2026-02-12 | 3, 4 | 2026-02-03 | 2026-02-12 | 10d | 0d |  | 1,213,072,641.67 | 1404/11/14 | 1404/11/23 |
| 76 | 3.3.4 | Hydrology Study Report | 10d | 2026-02-03 | 2026-02-12 | 3, 4 | 2026-02-03 | 2026-02-12 | 10d | 11d | 0d | 3,698,023.59 | 1404/11/14 | 1404/11/23 |
| 77 | 3.3.5 | Site Fence Detail Drawing | 10d | 2026-02-18 | 2026-02-27 | 108FS-5d | 2026-02-18 | 2026-02-27 | 10d | 5d | 0d | 99,185,401.51 | 1404/11/29 | 1404/12/8 |
| 78 | 3.3.6 | Logistic Area | 10d | 2026-01-31 | 2026-02-09 | 69 | 2026-01-31 | 2026-02-09 | 10d | 17d | 0d | 3,698,023.59 | 1404/11/11 | 1404/11/20 |
| 79 | 3.3.7 | Buildings Foundation & Structure Calculation | 10d | 2026-02-03 | 2026-02-12 | 5, 3, 4 | 2026-02-03 | 2026-02-12 | 10d | 0d |  | 212,260,377.5 | 1404/11/14 | 1404/11/23 |
| 80 | 3.3.8 | Buildings Foundation & Structure Drawing | 10d | 2026-02-08 | 2026-02-17 | 79FS-5d | 2026-02-08 | 2026-02-17 | 10d | 0d |  | 180,099,714.25 | 1404/11/19 | 1404/11/28 |
| 81 | 3.3.9 | Parking Foundation & Structure Detail Drawing | 10d | 2026-02-03 | 2026-02-12 | 5, 3, 4 | 2026-02-03 | 2026-02-12 | 10d | 24d |  | 3,433,879.05 | 1404/11/14 | 1404/11/23 |
| 82 | 3.3.10 | Power Plant Entrance Gate Drawing | 10d | 2026-02-22 | 2026-03-03 | 3, 77FS-6d, 4 | 2026-02-22 | 2026-03-03 | 10d | 22d | 0d | 18,936,832.86 | 1404/12/3 | 1404/12/12 |
| 83 | 3.3.11 | Parking Architectural Drawing | 10d | 2026-02-10 | 2026-02-19 | 78, 69 | 2026-02-10 | 2026-02-19 | 10d | 17d |  | 3,830,095.86 | 1404/11/21 | 1404/11/30 |
| 84 | 3.3.12 | Landscaping Layout | 9d | 2026-01-31 | 2026-02-08 | 69 | 2026-01-31 | 2026-02-08 | 9d | 1d | 0d | 3,830,095.86 | 1404/11/11 | 1404/11/19 |
| 85 | 3.3.13 | Buildings Architectural Detail drawing | 10d | 2026-02-12 | 2026-02-21 | 80FS-6d | 2026-02-12 | 2026-02-21 | 10d | 0d |  | 186,531,846.9 | 1404/11/23 | 1404/12/2 |
| 86 | 3.3.14 | Fence MTO | 9d | 2026-02-22 | 2026-03-02 | 77FS-6d | 2026-02-22 | 2026-03-02 | 9d | 5d | 0d | 88,558,394.21 | 1404/12/3 | 1404/12/11 |
| 87 | 3.3.15 | Site Grading and Leveling | 10d | 2026-02-13 | 2026-02-22 | 73, 3, 74, 4 | 2026-02-13 | 2026-02-22 | 10d | 14d |  | 408,598,591 | 1404/11/24 | 1404/12/3 |
| 88 | 3.3.16 | Drainage For Insite of Plant & Implementation Detail Drawing | 9d | 2026-02-13 | 2026-02-21 | 76, 69 | 2026-02-13 | 2026-02-21 | 9d | 11d | 0d | 1,256,396,664.59 | 1404/11/24 | 1404/12/2 |
| 89 | 3.3.17 | Flood Managmant For Outsite of Plant & Implementation Detail Drawing | 10d | 2026-02-16 | 2026-02-25 | 5FS-6d, 76FS-6d, 88FS-6d | 2026-02-16 | 2026-02-25 | 10d | 11d |  | 3,830,095.86 | 1404/11/27 | 1404/12/6 |
| 90 | 3.3.18 | Internal Road Layout & Implementation Detail Drawing | 10d | 2026-01-31 | 2026-02-09 | 69 | 2026-01-31 | 2026-02-09 | 10d | 19d | 0d | 308,306,209.5 | 1404/11/11 | 1404/11/20 |
| 91 | 3.3.19 | Access Road Layout & Implementation Detail Drawing | 10d | 2026-01-31 | 2026-02-09 | 69 | 2026-01-31 | 2026-02-09 | 10d | 19d | 0d | 308,306,209.5 | 1404/11/11 | 1404/11/20 |
| 92 | 3.3.20 | MV Station Foundation Calculation | 10d | 2026-01-28 | 2026-02-06 | 5, 7, 27 | 2026-01-28 | 2026-02-06 | 10d | 25d | 0d | 22,584,358.4 | 1404/11/8 | 1404/11/17 |
| 93 | 3.3.21 | MV Station Foundation Drawings | 10d | 2026-02-02 | 2026-02-11 | 92FS-5d | 2026-02-02 | 2026-02-11 | 10d | 25d |  | 18,192,955.38 | 1404/11/13 | 1404/11/22 |
| 94 | 3.3.22 | Auxiliary Transformer Foundation Detail Drawings | 10d | 2026-01-28 | 2026-02-06 | 34 | 2026-01-28 | 2026-02-06 | 10d | 30d |  | 18,192,955.38 | 1404/11/8 | 1404/11/17 |
| 95 | 3.3.23 | Calculation Report for Structure | 10d | 2026-02-07 | 2026-02-16 | 3, 69FS-6d, 75FS-6d, 4 | 2026-02-07 | 2026-02-16 | 10d | 0d |  | 231,556,775.46 | 1404/11/18 | 1404/11/27 |
| 96 | 3.3.24 | Structure Detail Drawings | 10d | 2026-02-13 | 2026-02-22 | 95FS-4d | 2026-02-13 | 2026-02-22 | 10d | 0d |  | 186,531,846.9 | 1404/11/24 | 1404/12/3 |
| 97 | 3.3.25 | PV Structure Ramming Location Details Drawing (Stacking) | 10d | 2026-02-07 | 2026-02-16 | 69FS-6d, 73FS-6d, 74FS-6d | 2026-02-07 | 2026-02-16 | 10d | 11d | 0d | 1,341,436,883.84 | 1404/11/18 | 1404/11/27 |
| 98 | 3.3.26 | Solar Module Structure MTO | 10d | 2026-02-17 | 2026-02-26 | 96FS-6d, 69FS-6d | 2026-02-17 | 2026-02-26 | 10d | 10d |  | 1,156,411,106.76 | 1404/11/28 | 1404/12/7 |
| 99 | 3.3.27 | Table UTM Point | 9d | 2026-02-17 | 2026-02-25 | 97 | 2026-02-17 | 2026-02-25 | 9d | 11d |  | 1,341,436,883.84 | 1404/11/28 | 1404/12/6 |
| 100 | 3.3.28 | Structure, Entrance Gate and Foundation of Building MTO | 10d | 2026-02-26 | 2026-03-07 | 82FS-6d, 80FS-6d, 85FS-6d | 2026-02-26 | 2026-03-07 | 10d | 22d | 0d | 18,208,493.14 | 1404/12/7 | 1404/12/16 |
| 101 | 3.3.29 | System Drainage Calculation | 10d | 2026-02-13 | 2026-02-22 | 3, 74, 4, 25 | 2026-02-13 | 2026-02-22 | 10d | 10d | 0d | 1,559,664,825.01 | 1404/11/24 | 1404/12/3 |
| 102 | 3.3.30 | Lighting Foundation Calculation | 5d | 2026-01-31 | 2026-02-04 | 69 | 2026-01-31 | 2026-02-04 | 5d | 5d | 0d | 8,503,422.46 | 1404/11/11 | 1404/11/15 |
| 103 | 3.3.31 | Lightning Foundation Calculation | 5d | 2026-01-28 | 2026-02-01 | 33 |  |  |  | 8d | 3d | 23,879,138.46 | 1404/11/8 | 1404/11/12 |
| 104 | 3.3.32 | Lightning Foundation Drawing | 5d | 2026-02-05 | 2026-02-09 | 102, 105, 103 | 2026-02-05 | 2026-02-09 | 5d | 5d | 0d | 18,572,663.25 | 1404/11/16 | 1404/11/20 |
| 105 | 3.3.33 | Lighting and CCTV Pole Calculation | 5d | 2026-01-31 | 2026-02-04 | 69 | 2026-01-31 | 2026-02-04 | 5d | 5d | 0d | 90,659,779.93 | 1404/11/11 | 1404/11/15 |
| 106 | 3.3.34 | Septic Tank Detail Drawing | 5d | 2026-02-10 | 2026-02-14 | 84, 43, 44, 42 | 2026-02-10 | 2026-02-14 | 5d | 0d |  | 3,233,375.59 | 1404/11/21 | 1404/11/25 |
| 107 | 3.3.35 | Water Tank Foundation Detail Drawing | 5d | 2026-02-09 | 2026-02-13 | 84 | 2026-02-09 | 2026-02-18 | 10d | 1d | 0d | 3,233,375.59 | 1404/11/20 | 1404/11/24 |
| 108 | 3.3.36 | Calculation for Fence | 10d | 2026-02-13 | 2026-02-22 | 3, 73, 4 | 2026-02-13 | 2026-02-22 | 10d | 5d | 0d | 99,185,401.51 | 1404/11/24 | 1404/12/3 |
| 109 | 3.3.37 | Material Requisition for Fence | 1d | 2026-03-03 | 2026-03-03 | 86 | 2026-03-03 | 2026-03-03 | 1d | 5d | 0d | 247,963,503.77 | 1404/12/12 | 1404/12/12 |

| ID | WBS | Task | Duration | Start | Finish | Predecessors | Baseline start | Baseline finish | Baseline duration | Total slack | Free slack | Cost | start shamsi | finish shamsi |
| --- | --- | --- | --- | --- | --- | --- | --- | --- | --- | --- | --- | --- | --- | --- |
| 110 | 3.4 | **طراحی و اخذ تاییدیه الکتریکال مطابق MDL ارایه شده** | 114d | 2026-01-28 | 2026-05-26 |  | 2026-01-28 | 2026-05-26 | 114d | 4d |  | 10,286,219,190.01 | 1404/11/8 | 1405/3/5 |
| 111 | 3.4.1 | Solar Module, Connector, Inverter and MV station MTO | 10d | 2026-02-05 | 2026-02-14 | 68, 69, 71, 70 | 2026-02-05 | 2026-02-14 | 10d | 8d | 0d | 832,615,996.87 | 1404/11/16 | 1404/11/25 |
| 112 | 3.4.2 | PV System Calculation Study (String Size, Optimum Tilt and Pitch) | 10d | 2026-02-01 | 2026-02-10 | 68 | 2026-02-01 | 2026-02-10 | 10d | 26d |  | 1,248,923,995.3 | 1404/11/12 | 1404/11/21 |
| 113 | 3.4.3 | Strings Connection Diagram & Inverter Arrangement (DC Side) | 10d | 2026-02-04 | 2026-02-13 | 69, 70 | 2026-02-04 | 2026-02-13 | 10d | 10d | 0d | 13,174,209.07 | 1404/11/15 | 1404/11/24 |
| 114 | 3.4.4 | Module & Table Arrangement (DC Side) | 10d | 2026-01-31 | 2026-02-09 | 69 | 2026-01-31 | 2026-02-09 | 10d | 14d | 4d | 971,385,329.68 | 1404/11/11 | 1404/11/20 |
| 115 | 3.4.5 | DC Cable Calculation | 10d | 2026-02-14 | 2026-02-23 | 113, 114, 123, 124 | 2026-02-14 | 2026-02-23 | 10d | 10d | 0d | 103,157,878.15 | 1404/11/25 | 1404/12/4 |
| 116 | 3.4.6 | DC Cable List, Labeling Code and MTO | 9d | 2026-02-18 | 2026-02-26 | 115FS-6d | 2026-02-18 | 2026-02-26 | 9d | 10d |  | 72,592,580.92 | 1404/11/29 | 1404/12/7 |
| 117 | 3.4.7 | LVAC Cable Calculation | 5d | 2026-02-10 | 2026-02-14 | 123, 124 | 2026-02-10 | 2026-02-14 | 5d | 9d | 0d | 177,979,178.57 | 1404/11/21 | 1404/11/25 |
| 118 | 3.4.8 | LV Cable Termination List and MTO | 9d | 2026-02-15 | 2026-02-23 | 117 | 2026-02-15 | 2026-02-23 | 9d | 9d | 0d | 92,285,500 | 1404/11/26 | 1404/12/4 |
| 119 | 3.4.9 | LV Cable List, Labeling Code and MTO | 4d | 2026-02-24 | 2026-02-27 | 118 | 2026-02-24 | 2026-02-27 | 4d | 9d |  | 125,244,607.14 | 1404/12/5 | 1404/12/8 |
| 120 | 3.4.10 | MV Cable Calculations | 5d | 2026-02-10 | 2026-02-14 | 123, 124 | 2026-02-10 | 2026-02-14 | 5d | 4d | 0d | 109,013,457.91 | 1404/11/21 | 1404/11/25 |
| 121 | 3.4.11 | MV Cable List, Labeling Code and MTO | 9d | 2026-02-15 | 2026-02-23 | 120 | 2026-02-15 | 2026-02-23 | 9d | 4d | 0d | 72,675,638.61 | 1404/11/26 | 1404/12/4 |
| 122 | 3.4.12 | MV Cable Termination List and MTO | 9d | 2026-02-24 | 2026-03-04 | 121 | 2026-02-24 | 2026-03-04 | 9d | 4d |  | 56,525,496.7 | 1404/12/5 | 1404/12/13 |
| 123 | 3.4.13 | Electrical Cable Route and Section | 10d | 2026-01-31 | 2026-02-09 | 69 | 2026-01-31 | 2026-02-09 | 10d | 4d | 0d | 32,469,967.93 | 1404/11/11 | 1404/11/20 |
| 124 | 3.4.14 | Cable Trench Layout | 10d | 2026-01-31 | 2026-02-09 | 69 | 2026-01-31 | 2026-02-09 | 10d | 4d | 0d | 222,871,959 | 1404/11/11 | 1404/11/20 |
| 125 | 3.4.15 | Earthing System Calculation | 5d | 2026-02-10 | 2026-02-14 | 123, 124 | 2026-02-10 | 2026-02-14 | 5d | 12d | 0d | 176,449,360.61 | 1404/11/21 | 1404/11/25 |
| 126 | 3.4.16 | Earthing System Layout | 10d | 2026-02-15 | 2026-02-24 | 125 | 2026-02-15 | 2026-02-24 | 10d | 12d |  | 143,773,553.09 | 1404/11/26 | 1404/12/5 |
| 127 | 3.4.17 | Lightning Protection Calculation | 5d | 2026-01-31 | 2026-02-04 | 69 | 2026-01-31 | 2026-02-04 | 5d | 12d | 0d | 17,909,353.85 | 1404/11/11 | 1404/11/15 |
| 128 | 3.4.18 | Lightning Protection Layout | 10d | 2026-02-05 | 2026-02-14 | 127 | 2026-02-05 | 2026-02-14 | 10d | 12d | 0d | 13,929,497.44 | 1404/11/16 | 1404/11/25 |
| 129 | 3.4.19 | Earthing and Lightning Protection MTO | 10d | 2026-02-15 | 2026-02-24 | 128 | 2026-02-15 | 2026-02-24 | 10d | 12d |  | 124,168,068.58 | 1404/11/26 | 1404/12/5 |
| 130 | 3.4.20 | Protection Single Line Diagram (PSLD) | 10d | 2026-02-04 | 2026-02-13 | 70 | 2026-02-04 | 2026-02-13 | 10d | 23d |  | 909,804,481.26 | 1404/11/15 | 1404/11/24 |
| 131 | 3.4.21 | CT and PT Calculations | 5d | 2026-02-04 | 2026-02-08 | 7, 70 | 2026-02-04 | 2026-02-08 | 5d | 5d | 0d | 12,035,085.73 | 1404/11/15 | 1404/11/19 |
| 132 | 3.4.22 | MV Switchgear Logic Diagram | 10d | 2026-02-09 | 2026-02-18 | 131 | 2026-02-09 | 2026-02-18 | 10d | 5d | 0d | 8,914,878.32 | 1404/11/20 | 1404/11/29 |
| 133 | 3.4.23 | Trip Table | 10d | 2026-02-19 | 2026-02-28 | 132 | 2026-02-19 | 2026-02-28 | 10d | 8d |  | 909,804,481.26 | 1404/11/30 | 1404/12/9 |
| 134 | 3.4.24 | Alarm List | 10d | 2026-02-19 | 2026-02-28 | 132 | 2026-02-19 | 2026-02-28 | 10d | 8d |  | 606,536,320.84 | 1404/11/30 | 1404/12/9 |
| 135 | 3.4.25 | Indoor and Outdoor Electrical Plan & Details for Building | 10d | 2026-01-31 | 2026-02-09 | 69 | 2026-01-31 | 2026-02-09 | 10d | 27d |  | 909,804,481.26 | 1404/11/11 | 1404/11/20 |
| 136 | 3.4.26 | MV Switchgear MTO | 10d | 2026-02-14 | 2026-02-23 | 7, 70, 27, 32, 147 | 2026-02-14 | 2026-02-23 | 10d | 13d |  | 8,469,134.4 | 1404/11/25 | 1404/12/4 |
| 137 | 3.4.27 | Load List | 9d | 2026-02-28 | 2026-03-08 | 142, 143, 162, 163, 170, 176, 177, 180, 68, 71 | 2026-02-28 | 2026-03-08 | 9d | 0d |  | 18,246,827.05 | 1404/12/9 | 1404/12/17 |
| 138 | 3.4.28 | LVAC Auxiliary Panel Single Line Diagram | 10d | 2026-01-28 | 2026-02-06 | 30, 31 | 2026-01-28 | 2026-02-06 | 10d | 5d | 0d | 138,428,250 | 1404/11/8 | 1404/11/17 |
| 139 | 3.4.29 | UPS Calculation | 5d | 2026-02-07 | 2026-02-11 | 138, 68, 71 | 2026-02-07 | 2026-02-11 | 5d | 5d | 0d | 15,900,011.56 | 1404/11/18 | 1404/11/22 |
| 140 | 3.4.30 | AUX Equipment MTO (AUX Transformer, Diesel, UPS, Battery) | 10d | 2026-02-12 | 2026-02-21 | 139 | 2026-02-12 | 2026-02-21 | 10d | 5d | 0d | 26,733,378.85 | 1404/11/23 | 1404/12/2 |
| 141 | 3.4.31 | Indoor and Outdoor Lighting Calculation | 5d | 2026-01-31 | 2026-02-04 | 69 | 2026-01-31 | 2026-02-04 | 5d | 1d | 0d | 6,377,566.85 | 1404/11/11 | 1404/11/15 |
| 142 | 3.4.32 | Outdoor Lighting Pole Drawing | 9d | 2026-02-05 | 2026-02-13 | 141 | 2026-02-05 | 2026-02-13 | 9d | 1d | 0d | 57,921,526.07 | 1404/11/16 | 1404/11/24 |
| 143 | 3.4.33 | Outdoor Lighting Layout and Switchboard | 9d | 2026-02-14 | 2026-02-22 | 142 | 2026-02-14 | 2026-02-22 | 9d | 1d | 0d | 5,432,742.13 | 1404/11/25 | 1404/12/3 |
| 144 | 3.4.34 | Lighting System MTO | 9d | 2026-02-23 | 2026-03-03 | 142, 143 | 2026-02-23 | 2026-03-03 | 9d | 1d | 0d | 4,487,917.41 | 1404/12/4 | 1404/12/12 |
| 145 | 3.4.35 | Special Tools | 10d | 2026-05-17 | 2026-05-26 | 242, 267, 273, 279, 285 | 2026-05-17 | 2026-05-26 | 10d | 109d |  | 953,128,504.17 | 1405/2/27 | 1405/3/5 |
| 146 | 3.4.36 | MV Switchgear Schematic Diagram | 5d | 2026-02-04 | 2026-02-08 | 7, 70 | 2026-02-04 | 2026-02-08 | 5d | 13d | 0d | 8,914,878.32 | 1404/11/15 | 1404/11/19 |
| 147 | 3.4.37 | MV Switchgear Front View Drawing | 5d | 2026-02-09 | 2026-02-13 | 146 | 2026-02-09 | 2026-02-13 | 5d | 13d | 0d | 8,914,878.32 | 1404/11/20 | 1404/11/24 |
| 148 | 3.4.38 | Material Requisition for Indoor Power and Lighting Distribution Panel | 5d | 2026-02-23 | 2026-02-27 | 142, 143 | 2026-02-23 | 2026-02-27 | 5d | 5d | 4d | 10,629,278.08 | 1404/12/4 | 1404/12/8 |
| 149 | 3.4.39 | Material Requisition for Auxiliary Transformer | 10d | 2026-02-22 | 2026-03-03 | 140 | 2026-02-22 | 2026-03-03 | 10d | 5d | 0d | 58,650,515.53 | 1404/12/3 | 1404/12/12 |
| 150 | 3.4.40 | Material Requisition for PCC | 10d | 2026-03-09 | 2026-03-18 | 137 | 2026-03-09 | 2026-03-18 | 10d | 79d | 0d | 58,650,515.53 | 1404/12/18 | 1404/12/27 |
| 151 | 3.4.41 | Material Requisition for MV Switchgear (CT, PT, Relay) | 10d | 2026-03-09 | 2026-03-18 | 70, 137, 156 | 2026-03-09 | 2026-03-18 | 10d | 137d | 5d | 20,058,476.22 | 1404/12/18 | 1404/12/27 |
| 152 | 3.4.42 | Material Requisition for AC Cable | 10d | 2026-03-09 | 2026-03-18 | 118, 122, 8 | 2026-03-09 | 2026-03-18 | 10d | 95d | 0d | 230,713,750 | 1404/12/18 | 1404/12/27 |
| 153 | 3.4.43 | Material Requisition for DC Cable | 10d | 2026-03-09 | 2026-03-18 | 116, 8 | 2026-03-09 | 2026-03-18 | 10d | 131d | 0d | 133,723,175.38 | 1404/12/18 | 1404/12/27 |
| 154 | 3.4.44 | Material Requisition for Earthing and Lightning | 10d | 2026-03-09 | 2026-03-18 | 129, 8 | 2026-03-09 | 2026-03-18 | 10d | 103d | 0d | 294,082,267.68 | 1404/12/18 | 1404/12/27 |
| 155 | 3.4.45 | Material Requisition for DC Connection (MC4) | 10d | 2026-03-09 | 2026-03-18 | 136, 142, 8 | 2026-03-09 | 2026-03-18 | 10d | 126d | 0d | 169,300,143.44 | 1404/12/18 | 1404/12/27 |
| 156 | 3.4.46 | Material Requisition for Lighting System | 8d | 2026-02-28 | 2026-03-07 | 144FS-4d, 148FS-4d | 2026-02-28 | 2026-03-07 | 8d | 1d | 0d | 10,629,278.08 | 1404/12/9 | 1404/12/16 |
| 157 | 3.4.47 | Material Requisition for UPS and Battery | 10d | 2026-03-04 | 2026-03-13 | 149 | 2026-03-04 | 2026-03-13 | 10d | 131d | 0d | 26,500,019.27 | 1404/12/13 | 1404/12/22 |
| 158 | 3.4.48 | Material Requisition for Diesel Generator | 10d | 2026-02-22 | 2026-03-03 | 140 |  |  |  | 149d | 0d | 56,280,797.58 | 1404/12/3 | 1404/12/12 |

| ID | WBS | Task | Duration | Start | Finish | Predecessors | Baseline start | Baseline finish | Baseline duration | Total slack | Free slack | Cost | start shamsi | finish shamsi |
| --- | --- | --- | --- | --- | --- | --- | --- | --- | --- | --- | --- | --- | --- | --- |
| 159 | 3.5 | **طراحی و اخذ تاییدیه مکانیکال مطابق MDL ارایه شده** | 18d | 2026-02-10 | 2026-02-27 |  | 2026-02-10 | 2026-02-27 | 18d | 0d |  | 44,532,819.73 | 1404/11/21 | 1404/12/8 |
| 160 | 3.5.1 | Solar Panel Cleaning & Maintenance Procedures | 4d | 2026-02-23 | 2026-02-26 | 101 | 2026-02-23 | 2026-02-26 | 4d | 10d |  | 6,686,158.74 | 1404/12/4 | 1404/12/7 |
| 161 | 3.5.2 | HVAC Equipment Calculation | 10d | 2026-02-10 | 2026-02-19 | 41 | 2026-02-10 | 2026-02-19 | 10d | 0d |  | 8,914,878.32 | 1404/11/21 | 1404/11/30 |
| 162 | 3.5.3 | HVAC Equipment Layout for Building | 4d | 2026-02-20 | 2026-02-23 | 85FS-6d, 161 | 2026-02-20 | 2026-02-23 | 4d | 0d |  | 8,914,878.32 | 1404/12/1 | 1404/12/4 |
| 163 | 3.5.4 | HVAC and Piping System MTO | 4d | 2026-02-24 | 2026-02-27 | 162 | 2026-02-24 | 2026-02-27 | 4d | 0d |  | 8,469,134.4 | 1404/12/5 | 1404/12/8 |
| 164 | 3.5.5 | Mechanical Drawing (Water Supply and Sewage Systems) | 4d | 2026-02-10 | 2026-02-13 | 78, 69 | 2026-02-10 | 2026-02-13 | 4d | 23d |  | 2,309,553.99 | 1404/11/21 | 1404/11/24 |
| 165 | 3.5.6 | Material Requisition for Septic Tank | 3d | 2026-02-15 | 2026-02-17 | 106 |  |  |  | 0d |  | 4,619,107.98 | 1404/11/26 | 1404/11/28 |
| 166 | 3.5.7 | Material Requisition for Water | 3d | 2026-02-14 | 2026-02-16 | 107 |  |  |  | 1d |  | 4,619,107.98 | 1404/11/25 | 1404/11/27 |
| 167 | 3.6 | **طراحی و اخذ تاییدیه ایمنی مطابق MDL ارایه شده** | 29d | 2026-02-16 | 2026-03-16 |  | 2026-02-16 | 2026-03-16 | 29d | 0d |  | 28,158,553.83 | 1404/11/27 | 1404/12/25 |
| 168 | 3.6.1 | Fire Fighting Equipment Arrangement of MV Switchgear Buildings | 8d | 2026-02-16 | 2026-02-23 | 85FS-6d | 2026-02-16 | 2026-02-23 | 8d | 0d |  | 4,867,318.67 | 1404/11/27 | 1404/12/4 |
| 169 | 3.6.2 | Outdoor Fire Fighting Equipment & Shelter Arrangement | 9d | 2026-02-20 | 2026-02-28 | 168FS-4d | 2026-02-20 | 2026-02-28 | 9d | 2d | 0d | 4,867,318.67 | 1404/12/1 | 1404/12/9 |
| 170 | 3.6.3 | Fire Alarm System Layout and Block Diagram | 8d | 2026-02-20 | 2026-02-27 | 168FS-4d | 2026-02-20 | 2026-02-27 | 8d | 0d |  | 2,276,648.95 | 1404/12/1 | 1404/12/8 |
| 171 | 3.6.4 | Fire and Safety and F & G System MTO | 10d | 2026-02-25 | 2026-03-06 | 169FS-4d, 45 | 2026-02-25 | 2026-03-06 | 10d | 2d | 0d | 4,867,318.67 | 1404/12/6 | 1404/12/15 |
| 172 | 3.6.5 | Material Requisition for Fire Alarm System | 10d | 2026-02-28 | 2026-03-09 | 170 | 2026-02-28 | 2026-03-09 | 10d | 156d | 0d | 3,594,708.87 | 1404/12/9 | 1404/12/18 |
| 173 | 3.6.6 | Material Requisition for Fire Fighting Equipment Arrangement | 10d | 2026-03-07 | 2026-03-16 | 171 | 2026-03-07 | 2026-03-16 | 10d | 136d | 0d | 7,685,240 | 1404/12/16 | 1404/12/25 |
| 174 | 3.7 | **طراحی و اخذ تاییدیه ارتباطی مطابق MDL ارایه شده** | 38d | 2026-02-04 | 2026-03-13 |  | 2026-02-04 | 2026-03-13 | 38d | 11d |  | 493,583,956.61 | 1404/11/15 | 1404/12/22 |
| 175 | 3.7.1 | CCTV System Block Diagram | 4d | 2026-02-10 | 2026-02-13 | 104 | 2026-02-10 | 2026-02-13 | 4d | 5d | 0d | 57,493,717.47 | 1404/11/21 | 1404/11/24 |
| 176 | 3.7.2 | CCTV System Arrangement & Layout | 4d | 2026-02-14 | 2026-02-17 | 175 | 2026-02-14 | 2026-02-17 | 4d | 5d | 0d | 57,493,717.47 | 1404/11/25 | 1404/11/28 |
| 177 | 3.7.3 | CCTV Pole Detail Drawing, Switchboard, CAFU Details | 4d | 2026-02-18 | 2026-02-21 | 176, 40 | 2026-02-18 | 2026-02-21 | 4d | 5d | 0d | 66,571,672.86 | 1404/11/29 | 1404/12/2 |
| 178 | 3.7.4 | CCTV System MTO | 10d | 2026-02-22 | 2026-03-03 | 177 | 2026-02-22 | 2026-03-03 | 10d | 5d | 0d | 54,467,732.34 | 1404/12/3 | 1404/12/12 |
| 179 | 3.7.5 | SCADA System I/O List | 4d | 2026-02-04 | 2026-02-07 | 7, 70 | 2026-02-04 | 2026-02-07 | 4d | 29d | 0d | 20,662,706.87 | 1404/11/15 | 1404/11/18 |
| 180 | 3.7.6 | Monitoring System Overall Diagram | 4d | 2026-02-19 | 2026-02-22 | 123, 132, 7, 37 | 2026-02-19 | 2026-02-22 | 4d | 5d | 0d | 29,518,152.67 | 1404/11/30 | 1404/12/3 |
| 181 | 3.7.7 | Telecommunication and Monitoring System MTO | 4d | 2026-02-23 | 2026-02-26 | 180 | 2026-02-23 | 2026-02-26 | 4d | 10d |  | 28,042,245.03 | 1404/12/4 | 1404/12/7 |
| 182 | 3.7.8 | Material Requisition forTelecommunication and Monitoring Cable | 5d | 2026-03-09 | 2026-03-13 | 179, 181, 184 | 2026-03-09 | 2026-03-13 | 5d | 150d | 0d | 44,277,229 | 1404/12/18 | 1404/12/22 |
| 183 | 3.7.9 | Material Requisition forFiber Optics | 5d | 2026-03-09 | 2026-03-13 | 179, 180, 184 | 2026-03-09 | 2026-03-13 | 5d | 112d | 0d | 44,277,229 | 1404/12/18 | 1404/12/22 |
| 184 | 3.7.10 | Material Requisition for CCTV and NVR | 5d | 2026-03-04 | 2026-03-08 | 178 | 2026-03-04 | 2026-03-08 | 5d | 110d | 0d | 90,779,553.9 | 1404/12/13 | 1404/12/17 |
| 185 | 3.7.11 | Material Requisition for Weather Station | 5d | 2026-02-08 | 2026-02-12 | 179 |  |  |  | 114d | 0d |  | 1404/11/19 | 1404/11/23 |

| ID | WBS | Task | Duration | Start | Finish | Predecessors | Baseline start | Baseline finish | Baseline duration | Total slack | Free slack | Cost | start shamsi | finish shamsi |
| --- | --- | --- | --- | --- | --- | --- | --- | --- | --- | --- | --- | --- | --- | --- |
| 186 | 4 | **تامین و حمل کالا تجهیزات** | 171d | 2026-01-27 | 2026-07-21 |  | 2026-01-27 | 2026-07-21 | 171d | 21d |  | 999,999,999,999.99 | 1404/11/7 | 1405/4/30 |
| 187 | 4.1 | **خرید و حمل داخلی** | 131d | 2026-01-27 | 2026-06-11 |  | 2026-01-27 | 2026-06-19 | 139d | 21d |  | 999,999,999,999.99 | 1404/11/7 | 1405/3/21 |
| 188 | 4.1.1 | **فنس پیرامونی** | 20d | 2026-03-04 | 2026-03-28 |  | 2026-03-04 | 2026-03-28 | 20d | 5d |  | 80,815,500,000 | 1404/12/13 | 1405/1/8 |
| 189 | 4.1.1.1 | استعلام قیمت فنس پیرامونی | 3d | 2026-03-04 | 2026-03-06 | 86, 109 | 2026-03-04 | 2026-03-06 | 3d | 5d | 0d | 4,040,775,000 | 1404/12/13 | 1404/12/15 |
| 190 | 4.1.1.2 | خرید فنس پیرامونی | 10d | 2026-03-07 | 2026-03-16 | 189 | 2026-03-07 | 2026-03-16 | 10d | 5d | 0d | 64,652,400,000 | 1404/12/16 | 1404/12/25 |
| 191 | 4.1.1.3 | حمل فنس پیرامونی | 7d | 2026-03-17 | 2026-03-28 | 190 | 2026-03-17 | 2026-03-28 | 7d | 5d |  | 12,122,325,000 | 1404/12/26 | 1405/1/8 |
| 192 | 4.1.2 | **تابلو های توزیع داخلی و روشنایی** | 28d | 2026-03-09 | 2026-04-10 |  | 2026-03-09 | 2026-04-10 | 28d | 147d |  | 213,288,000,000 | 1404/12/18 | 1405/1/21 |
| 193 | 4.1.2.1 | استعلام قیمت تابلو های توزیع داخلی و روشنایی | 1d | 2026-03-09 | 2026-03-09 | 70, 137, 156 | 2026-03-09 | 2026-03-09 | 1d | 147d | 0d | 10,664,400,000 | 1404/12/18 | 1404/12/18 |
| 194 | 4.1.2.2 | ساخت تابلو های توزیع داخلی و روشنایی | 20d | 2026-03-10 | 2026-04-03 | 193 | 2026-03-10 | 2026-04-03 | 20d | 147d | 0d | 170,630,400,000 | 1404/12/19 | 1405/1/14 |
| 195 | 4.1.2.3 | حمل تابلو های توزیع داخلی و روشنایی | 7d | 2026-04-04 | 2026-04-10 | 194 | 2026-04-04 | 2026-04-10 | 7d | 147d | 119d | 31,993,200,000 | 1405/1/15 | 1405/1/21 |
| 196 | 4.1.3 | **ترانسفورماتور های مصرف داخلی و دیزل ژنراتور** | 30d | 2026-03-04 | 2026-04-07 |  | 2026-03-04 | 2026-04-07 | 30d | 149d |  | 34,333,500,000 | 1404/12/13 | 1405/1/18 |
| 197 | 4.1.3.1 | استعلام قیمت ترانسفورماتور های مصرف داخلی و دیزل ژنراتور | 3d | 2026-03-04 | 2026-03-06 | 149, 158 | 2026-03-04 | 2026-03-06 | 3d | 149d | 0d | 1,716,675,000 | 1404/12/13 | 1404/12/15 |
| 198 | 4.1.3.2 | خرید ترانسفورماتور های مصرف داخلی و دیزل ژنراتور | 25d | 2026-03-07 | 2026-04-05 | 197 | 2026-03-07 | 2026-04-05 | 25d | 149d | 0d | 27,466,800,000 | 1404/12/16 | 1405/1/16 |
| 199 | 4.1.3.3 | حمل ترانسفورماتور های مصرف داخلی و دیزل ژنراتور | 7d | 2026-04-01 | 2026-04-07 | 198FS-5d | 2026-04-01 | 2026-04-07 | 7d | 149d |  | 5,150,025,000 | 1405/1/12 | 1405/1/18 |
| 200 | 4.1.4 | **تابلوهای پست سوییچگیر** | 80d | 2026-03-19 | 2026-06-11 |  | 2026-03-19 | 2026-06-11 | 80d | 79d |  | 106,644,000,000 | 1404/12/28 | 1405/3/21 |
| 201 | 4.1.4.1 | استعلام قیمت تابلوهای پست سوییچگیر | 5d | 2026-03-19 | 2026-03-28 | 132, 150 | 2026-03-19 | 2026-03-28 | 5d | 79d | 0d | 5,332,200,000 | 1404/12/28 | 1405/1/8 |
| 202 | 4.1.4.2 | ساخت تابلوهای پست سوییچگیر | 60d | 2026-03-29 | 2026-05-27 | 201 | 2026-03-29 | 2026-05-27 | 60d | 79d | 0d | 85,315,200,000 | 1405/1/9 | 1405/3/6 |
| 203 | 4.1.4.3 | حمل تابلوهای پست سوییچگیر | 15d | 2026-05-28 | 2026-06-11 | 202 | 2026-05-28 | 2026-06-11 | 15d | 79d | 57d | 15,996,600,000 | 1405/3/7 | 1405/3/21 |
| 204 | 4.1.5 | **ct& pt** | 28d | 2026-03-29 | 2026-04-25 |  | 2026-03-29 | 2026-04-25 | 28d | 132d |  | 106,644,000,000 | 1405/1/9 | 1405/2/5 |
| 205 | 4.1.5.1 | استعلام قیمت ct& pt | 1d | 2026-03-29 | 2026-03-29 | 151, 229 | 2026-03-29 | 2026-03-29 | 1d | 132d | 0d | 5,332,200,000 | 1405/1/9 | 1405/1/9 |
| 206 | 4.1.5.2 | خرید ct& pt | 20d | 2026-03-30 | 2026-04-18 | 205 | 2026-03-30 | 2026-04-18 | 20d | 132d | 0d | 85,315,200,000 | 1405/1/10 | 1405/1/29 |
| 207 | 4.1.5.3 | حمل ct& pt | 7d | 2026-04-19 | 2026-04-25 | 206 | 2026-04-19 | 2026-04-25 | 7d | 132d | 104d | 15,996,600,000 | 1405/1/30 | 1405/2/5 |
| 208 | 4.1.6 | **AC/LV و AC/MV کابل های** | 50d | 2026-03-19 | 2026-05-12 |  | 2026-03-19 | 2026-05-12 | 50d | 95d |  | 334,726,500,000 | 1404/12/28 | 1405/2/22 |
| 209 | 4.1.6.1 | AC/LV و AC/MV استعلام قیمت کابل های | 7d | 2026-03-19 | 2026-03-30 | 152 | 2026-03-19 | 2026-03-30 | 7d | 95d | 0d | 16,736,325,000 | 1404/12/28 | 1405/1/10 |
| 210 | 4.1.6.2 | AC/LV و AC/MV خرید کابل های | 36d | 2026-03-31 | 2026-05-05 | 209 | 2026-03-31 | 2026-05-05 | 36d | 95d | 0d | 267,781,200,000 | 1405/1/11 | 1405/2/15 |
| 211 | 4.1.6.3 | AC/LV و AC/MV حمل کابل های | 10d | 2026-05-03 | 2026-05-12 | 210FS-3d | 2026-05-03 | 2026-05-12 | 10d | 95d | 54d | 50,208,975,000 | 1405/2/13 | 1405/2/22 |

| ID | WBS | Task | Duration | Start | Finish | Predecessors | Baseline start | Baseline finish | Baseline duration | Total slack | Free slack | Cost | start shamsi | finish shamsi |
| --- | --- | --- | --- | --- | --- | --- | --- | --- | --- | --- | --- | --- | --- | --- |
| 212 | 4.1.7 | **DC کابل های** | 20d | 2026-03-19 | 2026-04-12 |  | 2026-03-19 | 2026-04-12 | 20d | 131d |  | 162,150,000,000 | 1404/12/28 | 1405/1/23 |
| 213 | 4.1.7.1 | DC استعلام قیمت کابل های | 3d | 2026-03-19 | 2026-03-26 | 153 | 2026-03-19 | 2026-03-26 | 3d | 131d | 0d | 8,107,500,000 | 1404/12/28 | 1405/1/6 |
| 214 | 4.1.7.2 | DC خرید کابل های | 10d | 2026-03-27 | 2026-04-05 | 213 | 2026-03-27 | 2026-04-05 | 10d | 131d | 0d | 129,720,000,000 | 1405/1/7 | 1405/1/16 |
| 215 | 4.1.7.3 | DC حمل کابل های | 7d | 2026-04-06 | 2026-04-12 | 214 | 2026-04-06 | 2026-04-12 | 7d | 131d |  | 24,322,500,000 | 1405/1/17 | 1405/1/23 |
| 216 | 4.1.8 | **کابل های ارتباطی** | 20d | 2026-03-14 | 2026-04-07 |  | 2026-03-14 | 2026-04-07 | 20d | 150d |  | 40,006,500,000 | 1404/12/23 | 1405/1/18 |
| 217 | 4.1.8.1 | استعلام قیمت کابل های ارتباطی | 3d | 2026-03-14 | 2026-03-16 | 182 | 2026-03-14 | 2026-03-16 | 3d | 150d | 0d | 2,000,325,000 | 1404/12/23 | 1404/12/25 |
| 218 | 4.1.8.2 | خرید کابل های ارتباطی | 10d | 2026-03-17 | 2026-03-31 | 217 | 2026-03-17 | 2026-03-31 | 10d | 150d | 0d | 32,005,200,000 | 1404/12/26 | 1405/1/11 |
| 219 | 4.1.8.3 | حمل کابل های ارتباطی | 7d | 2026-04-01 | 2026-04-07 | 218 | 2026-04-01 | 2026-04-07 | 7d | 150d | 92d | 6,000,975,000 | 1405/1/12 | 1405/1/18 |
| 220 | 4.1.9 | **Fiber Optics (انتقال دیتا داخلی نیروگاه)** | 50d | 2026-03-14 | 2026-05-07 |  | 2026-03-14 | 2026-05-07 | 50d | 112d |  | 40,006,500,000 | 1404/12/23 | 1405/2/17 |
| 221 | 4.1.9.1 | Fiber Optics استعلام قیمت (انتقال دیتا داخلی نیروگاه) | 10d | 2026-03-14 | 2026-03-28 | 183 | 2026-03-14 | 2026-03-28 | 10d | 112d | 0d | 2,000,325,000 | 1404/12/23 | 1405/1/8 |
| 222 | 4.1.9.2 | Fiber Optics خرید (انتقال دیتا داخلی نیروگاه) | 30d | 2026-03-29 | 2026-04-27 | 221 | 2026-03-29 | 2026-04-27 | 30d | 112d | 0d | 32,005,200,000 | 1405/1/9 | 1405/2/7 |
| 223 | 4.1.9.3 | Fiber Optics حمل (انتقال دیتا داخلی نیروگاه) | 10d | 2026-04-28 | 2026-05-07 | 222 | 2026-04-28 | 2026-05-07 | 10d | 112d | 54d | 6,000,975,000 | 1405/2/8 | 1405/2/17 |
| 224 | 4.1.10 | **کابل سیستم زمین و تجهیزات جانبی (ارت)** | 42d | 2026-03-19 | 2026-05-04 |  | 2026-03-19 | 2026-05-04 | 42d | 103d |  | 91,314,000,000 | 1404/12/28 | 1405/2/14 |
| 225 | 4.1.10.1 | استعلام قیمت کابل سیستم زمین و تجهیزات جانبی (ارت) | 5d | 2026-03-19 | 2026-03-28 | 154 | 2026-03-19 | 2026-03-28 | 5d | 103d | 0d | 4,565,700,000 | 1404/12/28 | 1405/1/8 |
| 226 | 4.1.10.2 | خرید کابل سیستم زمین و تجهیزات جانبی (ارت) | 30d | 2026-03-29 | 2026-04-27 | 225 | 2026-03-29 | 2026-04-27 | 30d | 103d | 0d | 73,051,200,000 | 1405/1/9 | 1405/2/7 |
| 227 | 4.1.10.3 | حمل کابل سیستم زمین و تجهیزات جانبی (ارت) | 7d | 2026-04-28 | 2026-05-04 | 226 | 2026-04-28 | 2026-05-04 | 7d | 103d | 57d | 13,697,100,000 | 1405/2/8 | 1405/2/14 |
| 228 | 4.1.11 | **MC4** | 32d | 2026-03-19 | 2026-04-24 |  | 2026-03-19 | 2026-04-24 | 32d | 126d |  | 191,760,000,000 | 1404/12/28 | 1405/2/4 |
| 229 | 4.1.11.1 | MC4 استعلام قیمت | 5d | 2026-03-19 | 2026-03-28 | 155 | 2026-03-19 | 2026-03-28 | 5d | 126d | 0d | 9,588,000,000 | 1404/12/28 | 1405/1/8 |
| 230 | 4.1.11.2 | MC4 خرید | 20d | 2026-03-29 | 2026-04-17 | 229 | 2026-03-29 | 2026-04-17 | 20d | 126d | 0d | 153,408,000,000 | 1405/1/9 | 1405/1/28 |
| 231 | 4.1.11.3 | MC4 حمل | 7d | 2026-04-18 | 2026-04-24 | 230 | 2026-04-18 | 2026-04-24 | 7d | 126d | 119d | 28,764,000,000 | 1405/1/29 | 1405/2/4 |
| 232 | 4.1.12 | **و تجهیزات جانبیCCTV سیستم** | 52d | 2026-03-04 | 2026-04-29 |  | 2026-03-04 | 2026-04-29 | 52d | 121d |  | 123,940,500,000 | 1404/12/13 | 1405/2/9 |
| 233 | 4.1.12.1 | و تجهیزات جانبیCCTV استعلام قیمت سیستم | 7d | 2026-03-04 | 2026-03-10 | 178 | 2026-03-04 | 2026-03-10 | 7d | 121d | 0d | 6,197,025,000 | 1404/12/13 | 1404/12/19 |
| 234 | 4.1.12.2 | و تجهیزات جانبیCCTV خرید سیستم | 35d | 2026-03-11 | 2026-04-19 | 233 | 2026-03-11 | 2026-04-19 | 35d | 121d | 0d | 99,152,400,000 | 1404/12/20 | 1405/1/30 |
| 235 | 4.1.12.3 | و تجهیزات جانبیCCTV حمل سیستم | 10d | 2026-04-20 | 2026-04-29 | 234 | 2026-04-20 | 2026-04-29 | 10d | 121d | 62d | 18,591,075,000 | 1405/1/31 | 1405/2/9 |

| ID | WBS | Task | Duration | Start | Finish | Predecessors | Baseline start | Baseline finish | Baseline duration | Total slack | Free slack | Cost | start shamsi | finish shamsi |
| --- | --- | --- | --- | --- | --- | --- | --- | --- | --- | --- | --- | --- | --- | --- |
| 236 | 4.1.13 | **تجهیزات سیستم روشنایی** | 55d | 2026-03-08 | 2026-05-06 |  | 2026-03-08 | 2026-05-06 | 55d | 110d |  | 16,767,000,000 | 1404/12/17 | 1405/2/16 |
| 237 | 4.1.13.1 | استعلام قیمت تجهیزات سیستم روشنایی | 5d | 2026-03-08 | 2026-03-12 | 156 | 2026-03-08 | 2026-03-12 | 5d | 110d | 0d | 838,350,000 | 1404/12/17 | 1404/12/21 |
| 238 | 4.1.13.2 | خرید تجهیزات سیستم روشنایی | 40d | 2026-03-13 | 2026-04-26 | 237 | 2026-03-13 | 2026-04-26 | 40d | 110d | 0d | 13,413,600,000 | 1404/12/22 | 1405/2/6 |
| 239 | 4.1.13.3 | حمل تجهیزات سیستم روشنایی | 10d | 2026-04-27 | 2026-05-06 | 238 | 2026-04-27 | 2026-05-06 | 10d | 110d | 55d | 2,515,050,000 | 1405/2/7 | 1405/2/16 |
| 240 | 4.1.14 | **UPS سیستم** | 37d | 2026-03-14 | 2026-04-24 |  | 2026-03-14 | 2026-04-24 | 37d | 131d |  | 17,371,500,000 | 1404/12/23 | 1405/2/4 |
| 241 | 4.1.14.1 | UPS استعلام قیمت سیستم | 10d | 2026-03-14 | 2026-03-28 | 157 | 2026-03-14 | 2026-03-28 | 10d | 131d | 0d | 868,575,000 | 1404/12/23 | 1405/1/8 |
| 242 | 4.1.14.2 | UPS خرید سیستم | 20d | 2026-03-29 | 2026-04-17 | 241 | 2026-03-29 | 2026-04-17 | 20d | 131d | 0d | 13,897,200,000 | 1405/1/9 | 1405/1/28 |
| 243 | 4.1.14.3 | UPS حمل سیستم | 7d | 2026-04-18 | 2026-04-24 | 242 | 2026-04-18 | 2026-04-24 | 7d | 131d | 118d | 2,605,725,000 | 1405/1/29 | 1405/2/4 |
| 244 | 4.1.15 | **سیستم اعلان حریق و تجهیزات جانبی** | 16d | 2026-03-10 | 2026-03-30 |  | 2026-03-10 | 2026-03-30 | 16d | 156d |  | 2,551,500,000 | 1404/12/19 | 1405/1/10 |
| 245 | 4.1.15.1 | استعلام قیمت سیستم اعلان حریق و تجهیزات جانبی | 2d | 2026-03-10 | 2026-03-11 | 172, 8, 169 | 2026-03-10 | 2026-03-11 | 2d | 156d | 0d | 127,575,000 | 1404/12/19 | 1404/12/20 |
| 246 | 4.1.15.2 | خرید سیستم اعلان حریق و تجهیزات جانبی | 7d | 2026-03-12 | 2026-03-18 | 245 | 2026-03-12 | 2026-03-18 | 7d | 156d | 0d | 2,041,200,000 | 1404/12/21 | 1404/12/27 |
| 247 | 4.1.15.3 | حمل سیستم اعلان حریق و تجهیزات جانبی | 7d | 2026-03-19 | 2026-03-30 | 246 | 2026-03-19 | 2026-03-30 | 7d | 156d | 42d | 382,725,000 | 1404/12/28 | 1405/1/10 |
| 248 | 4.1.16 | **سیستم اطفا حریق و تجهیزات جانبی** | 20d | 2026-03-17 | 2026-04-10 |  | 2026-03-17 | 2026-04-10 | 20d | 136d |  | 7,669,500,000 | 1404/12/26 | 1405/1/21 |
| 249 | 4.1.16.1 | استعلام قیمت سیستم اطفا حریق و تجهیزات جانبی | 3d | 2026-03-17 | 2026-03-19 | 169, 173, 8 | 2026-03-17 | 2026-03-19 | 3d | 136d | 0d | 383,475,000 | 1404/12/26 | 1404/12/28 |
| 250 | 4.1.16.2 | خرید سیستم اطفا حریق و تجهیزات جانبی | 10d | 2026-03-25 | 2026-04-03 | 249 | 2026-03-25 | 2026-04-03 | 10d | 136d | 0d | 6,135,600,000 | 1405/1/5 | 1405/1/14 |
| 251 | 4.1.16.3 | حمل سیستم اطفا حریق و تجهیزات جانبی | 7d | 2026-04-04 | 2026-04-10 | 250 | 2026-04-04 | 2026-04-10 | 7d | 136d | 41d | 1,150,425,000 | 1405/1/15 | 1405/1/21 |
| 252 | 4.1.17 | **ایستگاه هواشناسی و سنسورها** | 20d | 2026-02-13 | 2026-03-04 |  | 2026-03-09 | 2026-06-19 | 98d | 114d |  | 3,447,000,000 | 1404/11/24 | 1404/12/13 |
| 253 | 4.1.17.1 | استعلام قیمت ایستگاه هواشناسی و سنسورها | 3d | 2026-02-13 | 2026-02-15 | 185 | 2026-03-09 | 2026-04-07 | 25d | 114d | 0d | 172,350,000 | 1404/11/24 | 1404/11/26 |
| 254 | 4.1.17.2 | خرید ایستگاه هواشناسی و سنسورها | 10d | 2026-02-16 | 2026-02-25 | 253 |  |  |  | 114d | 0d | 2,757,600,000 | 1404/11/27 | 1404/12/6 |
| 255 | 4.1.17.3 | حمل ایستگاه هواشناسی و سنسورها | 7d | 2026-02-26 | 2026-03-04 | 254 |  |  |  | 114d | 0d | 517,050,000 | 1404/12/7 | 1404/12/13 |
| 256 | 4.1.18 | **لوازم یدکی** | 73d | 2026-03-09 | 2026-05-25 |  | 2026-04-08 | 2026-06-19 | 73d | 110d |  | 5,250,000,000 | 1404/12/18 | 1405/3/4 |
| 257 | 4.1.18.1 | لوازم یدکی | 73d | 2026-03-09 | 2026-05-25 | 179, 184, 255 |  |  |  | 110d |  |  | 1404/12/18 | 1405/3/4 |
| 258 | 4.1.19 | **مصالح و تجهیز کارگاه** | 70d | 2026-01-27 | 2026-04-11 |  | 2026-01-27 | 2026-04-11 | 70d | 21d |  | 229,844,060,827 | 1404/11/7 | 1405/1/22 |
| 259 | 4.1.19.1 | مصالح ساختمانی و ملزومات عمرانی | 30d | 2026-03-08 | 2026-04-11 | 100, 82 | 2026-03-08 | 2026-04-11 | 30d | 22d | 0d | 169,221,000,000 | 1404/12/17 | 1405/1/22 |
| 260 | 4.1.19.2 | مصالح ،تجهیزات و ملزومات برقی ساختمان ها | 30d | 2026-03-08 | 2026-04-11 | 100 | 2026-03-08 | 2026-04-11 | 30d | 110d | 30d | 14,694,000,000 | 1404/12/17 | 1405/1/22 |
| 261 | 4.1.19.3 | تانک سپتیک و دو مخزن 10 هزار لیتری سه لایه | 5d | 2026-02-18 | 2026-02-22 | 165, 166 | 2026-02-19 | 2026-02-23 | 5d | 0d |  | 3,673,500,000 | 1404/11/29 | 1404/12/3 |
| 262 | 4.1.19.4 | کلیه تجهیزات و ملزومات اداری | 15d | 2026-03-08 | 2026-03-27 | 100 | 2026-03-08 | 2026-03-27 | 15d | 146d | 0d | 7,347,000,000 | 1404/12/17 | 1405/1/7 |
| 263 | 4.1.19.5 | سایر خرید تجهیز کارگاه | 15d | 2026-01-27 | 2026-02-10 | 6 | 2026-01-27 | 2026-02-10 | 15d | 21d |  | 34,908,560,827 | 1404/11/7 | 1404/11/21 |

| ID | WBS | Task | Duration | Start | Finish | Predecessors | Baseline start | Baseline finish | Baseline duration | Total slack | Free slack | Cost | start shamsi | finish shamsi |
| --- | --- | --- | --- | --- | --- | --- | --- | --- | --- | --- | --- | --- | --- | --- |
| 264 | 4.2 | **خرید خارجی، حمل بین المللی و ترخیص** | 170d | 2026-01-28 | 2026-07-21 |  | 2026-01-28 | 2026-07-21 | 170d | 17d |  | 999,999,999,999.99 | 1404/11/8 | 1405/4/30 |
| 265 | 4.2.1 | **خرید سازه های نگهدارنده پنل ها و اینورترها** | 82d | 2026-02-23 | 2026-05-20 |  | 2026-02-23 | 2026-05-20 | 82d | 0d |  | 999,999,999,999.99 | 1404/12/4 | 1405/2/30 |
| 266 | 4.2.1.1 | استعلام قیمتی و سفارش گذاری سازه های نگهدارنده | 5d | 2026-02-23 | 2026-02-27 | 96, 111 | 2026-02-23 | 2026-02-27 | 5d | 0d |  | 184,827,825,000 | 1404/12/4 | 1404/12/8 |
| 267 | 4.2.1.2 | ساخت سازه های نگهدارنده و بازرسی قبل حمل | 20d | 2026-02-28 | 2026-03-19 | 266 | 2026-02-28 | 2026-03-19 | 20d | 0d |  | 554,483,475,000 | 1404/12/9 | 1404/12/28 |
| 268 | 4.2.1.3 | حمل خارجی سازه های نگهدارنده | 35d | 2026-03-25 | 2026-04-28 | 267 | 2026-03-25 | 2026-04-28 | 35d | 0d |  | 123,218,550,000 | 1405/1/5 | 1405/2/8 |
| 269 | 4.2.1.4 | ترخیص سازه های نگهدارنده | 15d | 2026-04-29 | 2026-05-13 | 268 | 2026-04-29 | 2026-05-13 | 15d | 0d |  | 61,609,275,000 | 1405/2/9 | 1405/2/23 |
| 270 | 4.2.1.5 | حمل داخلی سازه های نگهدارنده و تحویل در سایت | 7d | 2026-05-14 | 2026-05-20 | 269 | 2026-05-14 | 2026-05-20 | 7d | 0d |  | 308,046,375,000 | 1405/2/24 | 1405/2/30 |
| 271 | 4.2.2 | **خرید پنل های خورشیدی** | 127d | 2026-01-28 | 2026-06-08 |  | 2026-01-28 | 2026-06-08 | 127d | 13d |  |  | 1404/11/8 | 1405/3/18 |
| 272 | 4.2.2.1 | استعلام قیمتی و ثبت سفارش پنل های خورشیدی | 5d | 2026-01-28 | 2026-02-01 | 25 | 2026-01-28 | 2026-02-01 | 5d | 39d | 26d |  | 1404/11/8 | 1404/11/12 |
| 273 | 4.2.2.2 | ساخت پنل های خورشیدی و بازرسی قبل حمل | 30d | 2026-02-28 | 2026-04-03 | 272, 9 | 2026-02-28 | 2026-04-03 | 30d | 13d | 0d |  | 1404/12/9 | 1405/1/14 |
| 274 | 4.2.2.3 | حمل خارجی پنل های خورشیدی | 45d | 2026-04-04 | 2026-05-18 | 273 | 2026-04-04 | 2026-05-18 | 45d | 13d | 0d |  | 1405/1/15 | 1405/2/28 |
| 275 | 4.2.2.4 | ترخیص پنل های خورشیدی | 14d | 2026-05-19 | 2026-06-01 | 274 | 2026-05-19 | 2026-06-01 | 14d | 13d | 0d |  | 1405/2/29 | 1405/3/11 |
| 276 | 4.2.2.5 | حمل داخلی پنل های خورشیدی و تحویل در سایت | 7d | 2026-06-02 | 2026-06-08 | 275 | 2026-06-02 | 2026-06-08 | 7d | 13d |  |  | 1405/3/12 | 1405/3/18 |
| 277 | 4.2.3 | **خرید اینورترهای خورشیدی** | 152d | 2026-02-15 | 2026-07-21 |  | 2026-02-15 | 2026-07-21 | 152d | 17d |  |  | 1404/11/26 | 1405/4/30 |
| 278 | 4.2.3.1 | استعلام قیمتی ثبت سفارش اینورترهای خورشیدی | 7d | 2026-02-15 | 2026-02-21 | 111, 26 | 2026-02-15 | 2026-02-21 | 7d | 19d | 6d |  | 1404/11/26 | 1404/12/2 |
| 279 | 4.2.3.2 | ساخت اینورترهای خورشیدی و بازرسی قبل حمل | 73d | 2026-02-28 | 2026-05-16 | 278, 9 | 2026-02-28 | 2026-05-16 | 73d | 17d | 0d |  | 1404/12/9 | 1405/2/26 |
| 280 | 4.2.3.3 | حمل خارجی اینورترهای خورشیدی | 45d | 2026-05-17 | 2026-06-30 | 279 | 2026-05-17 | 2026-06-30 | 45d | 17d | 0d |  | 1405/2/27 | 1405/4/9 |
| 281 | 4.2.3.4 | ترخیص اینورترهای خورشیدی | 14d | 2026-07-01 | 2026-07-14 | 280 | 2026-07-01 | 2026-07-14 | 14d | 17d | 0d |  | 1405/4/10 | 1405/4/23 |
| 282 | 4.2.3.5 | حمل داخلی اینورترهای خورشیدی و تحویل در سایت | 7d | 2026-07-15 | 2026-07-21 | 281 | 2026-07-15 | 2026-07-21 | 7d | 17d | 0d |  | 1405/4/24 | 1405/4/30 |
| 283 | 4.2.4 | **خرید MV Station** | 152d | 2026-02-15 | 2026-07-21 |  | 2026-02-15 | 2026-07-21 | 152d | 17d |  |  | 1404/11/26 | 1405/4/30 |
| 284 | 4.2.4.1 | استعلام قیمتی ثبت سفارش MV Station | 7d | 2026-02-15 | 2026-02-21 | 111, 27 | 2026-02-15 | 2026-02-21 | 7d | 19d | 6d |  | 1404/11/26 | 1404/12/2 |
| 285 | 4.2.4.2 | ساخت MV Station و بازرسی قبل حمل | 73d | 2026-02-28 | 2026-05-16 | 284, 9 | 2026-02-28 | 2026-05-16 | 73d | 17d | 0d |  | 1404/12/9 | 1405/2/26 |
| 286 | 4.2.4.3 | حمل خارجی MV Station | 45d | 2026-05-17 | 2026-06-30 | 285 | 2026-05-17 | 2026-06-30 | 45d | 17d | 0d |  | 1405/2/27 | 1405/4/9 |
| 287 | 4.2.4.4 | ترخیص MV Station | 14d | 2026-07-01 | 2026-07-14 | 286 | 2026-07-01 | 2026-07-14 | 14d | 17d | 0d |  | 1405/4/10 | 1405/4/23 |
| 288 | 4.2.4.5 | حمل داخلی MV Station و تحویل در سایت | 7d | 2026-07-15 | 2026-07-21 | 287 | 2026-07-15 | 2026-07-21 | 7d | 17d | 0d |  | 1405/4/24 | 1405/4/30 |

Notes:
- 271: باراندازی کلی
- 273: 28 سنت یرو

| ID | WBS | Task | Duration | Start | Finish | Predecessors | Baseline start | Baseline finish | Baseline duration | Total slack | Free slack | Cost | start shamsi | finish shamsi |
| --- | --- | --- | --- | --- | --- | --- | --- | --- | --- | --- | --- | --- | --- | --- |
| 289 | 5 | **عملیات اجرایی** | 203d | 2026-02-10 | 2026-09-05 |  | 2026-02-10 | 2026-09-06 | 204d | 7d |  | 440,655,722,904 | 1404/11/21 | 1405/6/14 |
| 290 | 5.1 | **تجهیز کارگاه** | 14d | 2026-02-23 | 2026-03-08 |  | 2026-02-24 | 2026-03-09 | 14d | 0d |  | 9,028,877,850 | 1404/12/4 | 1404/12/17 |
| 291 | 5.1.1 | تانک سپتیک و دو مخزن 10 هزار لیتری سه لایه | 6d | 2026-02-23 | 2026-02-28 | 6, 261 | 2026-02-24 | 2026-03-01 | 6d | 0d |  | 456,377,850 | 1404/12/4 | 1404/12/9 |
| 292 | 5.1.2 | کانکس نگهبانی | 3d | 2026-03-01 | 2026-03-03 | 291, 6 | 2026-03-02 | 2026-03-04 | 3d | 0d |  | 8,572,500,000 | 1404/12/10 | 1404/12/12 |
| 293 | 5.1.3 | سایر تجهیز کارگاه | 5d | 2026-03-04 | 2026-03-08 | 292, 6, 263, 78 | 2026-03-05 | 2026-03-09 | 5d | 0d |  |  | 1404/12/13 | 1404/12/17 |
| 294 | 5.2 | **اجرای جاده دسترسی تا جاده اصلی** | 8d | 2026-02-10 | 2026-02-17 |  | 2026-02-10 | 2026-02-17 | 8d | 19d |  | 12,626,453,861 | 1404/11/21 | 1404/11/28 |
| 295 | 5.2.1 | زیرسازی | 6d | 2026-02-10 | 2026-02-15 | 90, 91 | 2026-02-10 | 2026-02-15 | 6d | 19d | 0d | 6,313,226,930.5 | 1404/11/21 | 1404/11/26 |
| 296 | 5.2.2 | شن ریزی | 2d | 2026-02-16 | 2026-02-17 | 295 | 2026-02-16 | 2026-02-17 | 2d | 19d |  | 6,313,226,930.5 | 1404/11/27 | 1404/11/28 |
| 297 | 5.3 | **عملیات عمرانی** | 174d | 2026-03-09 | 2026-09-03 |  | 2026-03-10 | 2026-09-04 | 174d | 0d |  | 41,630,640,187.4 | 1404/12/18 | 1405/6/12 |
| 298 | 5.3.1 | **عملیات دسترسی و آماده سازی سایت** | 86d | 2026-03-09 | 2026-06-07 |  | 2026-03-10 | 2026-06-07 | 85d | 0d |  | 3,042,519,003.4 | 1404/12/18 | 1405/3/17 |
| 299 | 5.3.1.1 | تسطیح و تحکیم زمین | 20d | 2026-03-09 | 2026-04-02 | 87, 292, 8, 293, 11, 296 | 2026-03-10 | 2026-04-03 | 20d | 0d |  | 1,673,385,451.4 | 1404/12/18 | 1405/1/13 |
| 300 | 5.3.1.2 | اجرای گیت ورودی | 15d | 2026-05-12 | 2026-05-26 | 82, 306, 259FS-5d | 2026-05-13 | 2026-05-27 | 15d | 0d |  | 760,629,751 | 1405/2/22 | 1405/3/5 |
| 301 | 5.3.1.3 | احداث پارکینگ مسقف | 7d | 2026-06-01 | 2026-06-07 | 81, 83, 332 | 2026-06-01 | 2026-06-07 | 7d | 97d |  | 608,503,801 | 1405/3/11 | 1405/3/17 |
| 302 | 5.3.2 | **اجرای سیستم زهکشی** | 40d | 2026-04-03 | 2026-05-12 |  | 2026-04-04 | 2026-05-13 | 40d | 85d |  | 6,693,541,805.6 | 1405/1/14 | 1405/2/22 |
| 303 | 5.3.2.1 | اجرای سیستم زهکشی | 40d | 2026-04-03 | 2026-05-12 | 76, 88, 299 |  |  |  | 85d | 39d |  | 1405/1/14 | 1405/2/22 |
| 304 | 5.3.3 | **اجرای فنس پیرامونی** | 39d | 2026-04-03 | 2026-05-11 |  | 2026-04-04 | 2026-05-12 | 39d | 0d |  | 10,953,068,410 | 1405/1/14 | 1405/2/21 |
| 305 | 5.3.3.1 | اجرای فونداسیون و پایه فنس | 24d | 2026-04-03 | 2026-04-26 | 86, 291, 299, 109, 191 | 2026-04-04 | 2026-04-27 | 24d | 0d |  | 912,755,701 | 1405/1/14 | 1405/2/6 |
| 306 | 5.3.3.2 | اجرای فنس | 35d | 2026-04-07 | 2026-05-11 | 305SS+4d | 2026-04-08 | 2026-05-12 | 35d | 0d |  | 10,040,312,709 | 1405/1/18 | 1405/2/21 |
| 307 | 5.3.4 | **اجرای فونداسیون MV Station** | 33d | 2026-06-17 | 2026-07-19 |  | 2026-06-18 | 2026-07-20 | 33d | 43d |  | 346,847,166.4 | 1405/3/27 | 1405/4/28 |
| 308 | 5.3.4.1 | گودبرداری فونداسیون | 3d | 2026-06-17 | 2026-06-19 | 93, 319 | 2026-06-18 | 2026-06-20 | 3d | 43d | 0d | 173,423,583.2 | 1405/3/27 | 1405/3/29 |
| 309 | 5.3.4.2 | بتن ریزی فونداسیون | 30d | 2026-06-20 | 2026-07-19 | 308 | 2026-06-21 | 2026-07-20 | 30d | 43d | 2d | 173,423,583.2 | 1405/3/30 | 1405/4/28 |
| 310 | 5.3.5 | **ساختمان پست سوییچگیر** | 118d | 2026-04-12 | 2026-08-07 |  | 2026-04-12 | 2026-08-07 | 118d | 22d |  | 8,268,609,695.5 | 1405/1/23 | 1405/5/16 |
| 311 | 5.3.5.1 | اجرای فونداسیون ساختمان پست سوییچگیر | 28d | 2026-04-12 | 2026-05-09 | 80, 76, 87, 89, 163, 291, 259 | 2026-04-12 | 2026-05-09 | 28d | 22d | 0d | 1,150,072,183.05 | 1405/1/23 | 1405/2/19 |
| 312 | 5.3.5.2 | سفت کاری ساختمان پست سوییچگیر | 60d | 2026-05-10 | 2026-07-08 | 311 | 2026-05-10 | 2026-07-08 | 60d | 22d | 0d | 3,450,216,549.15 | 1405/2/20 | 1405/4/17 |
| 313 | 5.3.5.3 | اجرای تاسیسات ساختمان پست سوییچگیر | 10d | 2026-07-09 | 2026-07-18 | 312, 260 | 2026-07-09 | 2026-07-18 | 10d | 22d | 0d | 766,714,788.7 | 1405/4/18 | 1405/4/27 |
| 314 | 5.3.5.4 | نازک کاری ساختمان پست سوییچگیر | 10d | 2026-07-19 | 2026-07-28 | 313 | 2026-07-19 | 2026-07-28 | 10d | 22d | 0d | 383,357,394.35 | 1405/4/28 | 1405/5/6 |
| 315 | 5.3.5.5 | اجرای نمای ساختمان پست سوییچگیر | 10d | 2026-07-29 | 2026-08-07 | 314 | 2026-07-29 | 2026-08-07 | 10d | 22d | 0d | 1,916,786,971.75 | 1405/5/7 | 1405/5/16 |
| 316 | 5.3.5.6 | اجرای سیستم اعلام حریق ساختمان پست سوییچگیر | 5d | 2026-07-09 | 2026-07-13 | 312, 247 | 2026-07-09 | 2026-07-13 | 5d | 56d | 28d | 150,365,452.2 | 1405/4/18 | 1405/4/22 |
| 317 | 5.3.5.7 | اجرای سیستم اطفا حریق ساختمان پست سوییچگیر | 5d | 2026-07-19 | 2026-07-23 | 313, 251 | 2026-07-19 | 2026-07-23 | 5d | 37d | 15d | 451,096,356.3 | 1405/4/28 | 1405/5/1 |

Notes:
- 302: پیانکار سفت کاری ساختمان در زمان دیار چیی استارت ای عملیت را نی می تواند بزند.بدلی عدم مناسب بودن اجرا در روزهای ابتدایی بدلی تردد ماشی آلات و موارد دیر که موجب بار آمدن خرابی کانال میود.

| ID | WBS | Task | Duration | Start | Finish | Predecessors | Baseline start | Baseline finish | Baseline duration | Total slack | Free slack | Cost | start shamsi | finish shamsi |
| --- | --- | --- | --- | --- | --- | --- | --- | --- | --- | --- | --- | --- | --- | --- |
| 318 | 5.3.6 | **ساختمان مانیتورینگ** | 160d | 2026-03-28 | 2026-09-03 |  | 2026-03-28 | 2026-09-04 | 161d | 4d |  | 11,060,685,186 | 1405/1/8 | 1405/6/12 |
| 319 | 5.3.6.1 | اجرای فونداسیون ساختمان مانیتورینگ | 21d | 2026-05-27 | 2026-06-16 | 80FS-6d, 76, 87, 89, 163, 291, 300, 259 | 2026-05-28 | 2026-06-17 | 21d | 0d |  | 894,500,586.8 | 1405/3/6 | 1405/3/26 |
| 320 | 5.3.6.2 | سفت کاری ساختمان مانیتورینگ | 50d | 2026-06-17 | 2026-08-05 | 319 | 2026-06-18 | 2026-08-06 | 50d | 0d |  | 3,578,002,347.2 | 1405/3/27 | 1405/5/14 |
| 321 | 5.3.6.3 | اجرای تاسیسات ساختمان مانیتورینگ | 10d | 2026-08-06 | 2026-08-15 | 320 | 2026-08-07 | 2026-08-16 | 10d | 0d |  | 2,683,501,760.4 | 1405/5/15 | 1405/5/24 |
| 322 | 5.3.6.4 | نازک کاری ساختمان مانیتورینگ | 10d | 2026-08-16 | 2026-08-25 | 321 | 2026-08-17 | 2026-08-26 | 10d | 0d |  | 894,500,586.8 | 1405/5/25 | 1405/6/3 |
| 323 | 5.3.6.5 | اجرای نمای ساختمان مانیتورینگ | 9d | 2026-08-26 | 2026-09-03 | 322, 326 | 2026-08-27 | 2026-09-04 | 9d | 0d |  | 894,500,586.8 | 1405/6/4 | 1405/6/12 |
| 324 | 5.3.6.6 | اجرای سیستم اعلام حریق ساختمان مانیتورینگ | 5d | 2026-08-06 | 2026-08-10 | 320, 247 | 2026-08-07 | 2026-08-11 | 5d | 28d | 0d | 300,730,904.4 | 1405/5/15 | 1405/5/19 |
| 325 | 5.3.6.7 | اجرای سیستم اطفا حریق ساختمان مانیتورینگ | 5d | 2026-08-16 | 2026-08-20 | 321, 251 | 2026-08-17 | 2026-08-21 | 5d | 13d | 0d | 902,192,712.6 | 1405/5/25 | 1405/5/29 |
| 326 | 5.3.6.8 | کلیه تجهیزات و ملزومات | 5d | 2026-03-28 | 2026-04-01 | 78, 262 | 2026-03-28 | 2026-04-01 | 5d | 146d |  | 912,755,701 | 1405/1/8 | 1405/1/12 |
| 327 | 5.3.7 | **ساختمان نگهبانی** | 50d | 2026-04-12 | 2026-05-31 |  | 2026-04-12 | 2026-05-31 | 50d | 97d |  | 1,265,368,920.5 | 1405/1/23 | 1405/3/10 |
| 328 | 5.3.7.1 | اجرای فونداسیون ساختمان نگهبانی | 10d | 2026-04-12 | 2026-04-21 | 80, 76, 87, 89, 163, 291, 259 | 2026-04-12 | 2026-04-21 | 10d | 97d | 0d | 106,488,165.1 | 1405/1/23 | 1405/2/1 |
| 329 | 5.3.7.2 | سفت کاری ساختمان نگهبانی | 20d | 2026-04-22 | 2026-05-11 | 328 | 2026-04-22 | 2026-05-11 | 20d | 97d | 0d | 425,952,660.4 | 1405/2/2 | 1405/2/21 |
| 330 | 5.3.7.3 | اجرای تاسیسات ساختمان نگهبانی | 10d | 2026-05-12 | 2026-05-21 | 329, 260 | 2026-05-12 | 2026-05-21 | 10d | 97d | 0d | 319,464,495.3 | 1405/2/22 | 1405/2/31 |
| 331 | 5.3.7.4 | نازک کاری ساختمان نگهبانی | 5d | 2026-05-22 | 2026-05-26 | 330 | 2026-05-22 | 2026-05-26 | 5d | 97d | 0d | 106,488,165.1 | 1405/3/1 | 1405/3/5 |
| 332 | 5.3.7.5 | اجرای نمای ساختمان نگهبانی | 5d | 2026-05-27 | 2026-05-31 | 331 | 2026-05-27 | 2026-05-31 | 5d | 97d | 0d | 106,488,165.1 | 1405/3/6 | 1405/3/10 |
| 333 | 5.3.7.6 | اجرای سیستم اعلام حریق ساختمان نگهبانی | 2d | 2026-05-12 | 2026-05-13 | 329, 247 | 2026-05-12 | 2026-05-13 | 2d | 117d | 89d | 50,121,817.4 | 1405/2/22 | 1405/2/23 |
| 334 | 5.3.7.7 | اجرای سیستم اطفا حریق ساختمان نگهبانی | 2d | 2026-05-22 | 2026-05-23 | 330, 251 | 2026-05-22 | 2026-05-23 | 2d | 107d | 89d | 150,365,452.1 | 1405/3/1 | 1405/3/2 |
| 335 | 5.4 | **عملیات مکانیکال** | 141d | 2026-04-03 | 2026-08-21 |  | 2026-04-04 | 2026-08-21 | 140d | 0d |  | 148,100,582,497 | 1405/1/14 | 1405/5/30 |
| 336 | 5.4.1 | نقشه برداری پایه ها و میخ کوبی | 6d | 2026-04-03 | 2026-04-08 | 69, 87, 99, 299 | 2026-04-04 | 2026-04-09 | 6d | 42d |  | 7,405,029,124.85 | 1405/1/14 | 1405/1/19 |
| 337 | 5.4.2 | پایه کوبی | 46d | 2026-05-21 | 2026-07-05 | 336, 270 | 2026-05-21 | 2026-07-05 | 46d | 0d |  | 7,405,029,124.85 | 1405/2/31 | 1405/4/14 |
| 338 | 5.4.3 | نصب متعلقات استراکچرها | 56d | 2026-05-25 | 2026-07-19 | 337SS+4d, 98 | 2026-05-25 | 2026-07-19 | 56d | 0d |  | 66,645,262,123.65 | 1405/3/4 | 1405/4/28 |
| 339 | 5.4.4 | نصب پنل ها | 61d | 2026-06-22 | 2026-08-21 | 338FS-5%, 276 | 2026-06-22 | 2026-08-21 | 61d | 0d |  | 66,645,262,123.65 | 1405/4/1 | 1405/5/30 |
| 340 | 5.5 | **عملیات الکتریکال** | 77d | 2026-06-21 | 2026-09-05 |  | 2026-06-21 | 2026-09-06 | 78d | 2d |  | 229,269,168,508.6 | 1405/3/31 | 1405/6/14 |
| 341 | 5.5.1 | اجرای ترانشه و کانال عبور فیبر نوری | 10d | 2026-06-21 | 2026-06-30 | 337FS-15d, 124, 123, 303 | 2026-06-21 | 2026-06-30 | 10d | 46d | 0d | 4,563,778,504 | 1405/3/31 | 1405/4/9 |
| 342 | 5.5.2 | نصب سازه اینورتر و وایرینگ اینورترهای سایت | 8d | 2026-07-22 | 2026-07-29 | 282, 270, 10 | 2026-07-22 | 2026-07-29 | 8d | 17d | 0d | 1,213,965,082.4 | 1405/4/31 | 1405/5/7 |
| 343 | 5.5.3 | اجرای سیستم زمین نیروگاه | 15d | 2026-07-01 | 2026-07-15 | 341, 126, 227 | 2026-07-01 | 2026-07-15 | 15d | 46d | 0d | 50,242,546,767 | 1405/4/10 | 1405/4/24 |
| 344 | 5.5.4 | تابلوهای فشار متوسط و کلیه متعلقات | 5d | 2026-08-08 | 2026-08-12 | 315, 317, 203 | 2026-08-08 | 2026-08-12 | 5d | 22d | 0d | 10,024,363,471 | 1405/5/17 | 1405/5/21 |
| 345 | 5.5.5 | تابلوهای فشار ضعیف و کلیه متعلقات | 2d | 2026-08-08 | 2026-08-09 | 135, 315, 195, 207 | 2026-08-08 | 2026-08-09 | 2d | 28d | 0d | 7,518,272,603 | 1405/5/17 | 1405/5/18 |
| 346 | 5.5.6 | کلیه کابل های فشار ضعیف نیروگاهac | 15d | 2026-07-30 | 2026-08-13 | 341, 119, 123, 342, 16, 211 | 2026-07-30 | 2026-08-13 | 15d | 17d | 0d | 46,046,932,191 | 1405/5/8 | 1405/5/22 |
| 347 | 5.5.7 | کلیه کابل های فشار متوسط نیروگاهac | 6d | 2026-07-06 | 2026-07-11 | 341FS+5d, 123, 69, 211 | 2026-07-06 | 2026-07-11 | 6d | 50d | 0d | 18,813,582,157 | 1405/4/15 | 1405/4/20 |
| 348 | 5.5.8 | کابل dc | 14d | 2026-08-22 | 2026-09-04 | 339, 338FS-10d, 12FS-10d, 13FS-10d, 215 | 2026-08-22 | 2026-09-04 | 14d | 0d |  | 23,457,010,522 | 1405/5/31 | 1405/6/13 |
| 349 | 5.5.9 | اجرای کابل های فیبر نوری | 3d | 2026-07-01 | 2026-07-03 | 341, 223 | 2026-07-01 | 2026-07-03 | 3d | 58d | 0d | 1,253,045,434 | 1405/4/10 | 1405/4/12 |
| 350 | 5.5.10 | نصب ایستگاه هواشناسی و سنسورها | 3d | 2026-07-24 | 2026-07-26 | 351, 255 | 2026-07-24 | 2026-07-26 | 3d | 41d | 39d |  | 1405/5/2 | 1405/5/4 |
| 351 | 5.5.11 | MV Station نصب | 2d | 2026-07-22 | 2026-07-23 | 309, 288, 10 | 2026-07-22 | 2026-07-23 | 2d | 41d | 0d | 173,423,583.2 | 1405/4/31 | 1405/5/1 |
| 352 | 5.5.12 | اجرای کلیه ملزومات و تجهیزات مربوط به ایجاد شبکه انتقال دیتا و بستر مخابراتی با پست بالادست به جز فیبر نوری | 3d | 2026-07-09 | 2026-07-11 | 349FS+5d, 219 | 2026-07-09 | 2026-07-11 | 3d | 58d | 0d | 9,773,754,384 | 1405/4/18 | 1405/4/20 |
| 353 | 5.5.13 | نصب ترانسفورماتور کمکی و دیزل | 1d | 2026-09-04 | 2026-09-04 | 325, 323, 94, 14, 199 | 2026-09-05 | 2026-09-05 | 1d | 0d |  | 6,265,227,169 | 1405/6/13 | 1405/6/13 |
| 354 | 5.5.14 | نصب یو پی اس | 1d | 2026-08-21 | 2026-08-21 | 325, 315, 243 | 2026-08-22 | 2026-08-22 | 1d | 13d | 0d | 3,257,918,128 | 1405/5/30 | 1405/5/30 |
| 355 | 5.5.15 | سیستم حفاظت صاعقه | 2d | 2026-07-18 | 2026-07-19 | 130, 409, 227 | 2026-07-18 | 2026-07-19 | 2d | 46d | 0d | 5,012,181,735 | 1405/4/27 | 1405/4/28 |
| 356 | 5.5.16 | اجرای کلیه ملزومات و تجهیزات مربوط به ایجاد شبکه انتقال دیتا و ارسال دیتا | 2d | 2026-09-04 | 2026-09-05 | 349, 315, 323, 350, 15, 223, 219 | 2026-09-05 | 2026-09-06 | 2d | 2d | 0d | 3,909,501,754 | 1405/6/13 | 1405/6/14 |

Notes:
- 341: پیانکار جدا دارد
- 342: هزیه ارتیگش هم ایجا دیه شده
- 343: اجرای برق گی و صاعقه گی رو هم با سیتم ارت دیم
- 348: به همراه سوکت زنی mc4
- 350: قبل مانیوریگ بای نصب و راه اندازی بشه
- 352: ای همون اسکادا هست که کار جمع آوری دیا رو انجام میه / کابل های دیا که تموم شد میه کارای راه اندازیم انجام دد و تستش کرد
- 356: اسکادا رو همپوشانی با خط انتقال انجام بده اما آر تی ی بای بعد اجرای بستر ارتباطی اجرا و نهایی بشه / هماهنگی های زیدی داره / اسکادا جمع آوری اطلاعات داخل سایه،آر تی ی برای انتقال دیای جمع آوری شده تویط اسکادا به سایه

| ID | WBS | Task | Duration | Start | Finish | Predecessors | Baseline start | Baseline finish | Baseline duration | Total slack | Free slack | Cost | start shamsi | finish shamsi |
| --- | --- | --- | --- | --- | --- | --- | --- | --- | --- | --- | --- | --- | --- | --- |
| 357 | 5.5.17 | **کلیه متعلقات مربوط به کابل کشی و سیم کشی** | 46d | 2026-07-12 | 2026-08-26 |  | 2026-07-12 | 2026-08-26 | 46d | 7d |  | 16,486,142,980 | 1405/4/21 | 1405/6/4 |
| 358 | 5.5.17.1 | نصب لدر | 3d | 2026-08-08 | 2026-08-10 | 315, 347 | 2026-08-08 | 2026-08-10 | 3d | 23d | 16d | 4,121,535,745 | 1405/5/17 | 1405/5/19 |
| 359 | 5.5.17.2 | اجرای لوله پلی اتیلن و فلکسی | 5d | 2026-08-22 | 2026-08-26 | 348SS, 338, 231 | 2026-08-22 | 2026-08-26 | 5d | 7d | 0d | 4,121,535,745 | 1405/5/31 | 1405/6/4 |
| 360 | 5.5.17.3 | اجرای سرسیم و کابل شو | 3d | 2026-08-14 | 2026-08-16 | 346 | 2026-08-14 | 2026-08-16 | 3d | 17d | 10d | 4,121,535,745 | 1405/5/23 | 1405/5/25 |
| 361 | 5.5.17.4 | اجرای سر کابل | 2d | 2026-07-12 | 2026-07-13 | 347 | 2026-07-12 | 2026-07-13 | 2d | 51d | 44d | 4,121,535,745 | 1405/4/21 | 1405/4/22 |
| 362 | 5.5.18 | **نصب سیستم روشنایی** | 14d | 2026-07-01 | 2026-07-14 |  | 2026-07-01 | 2026-07-14 | 14d | 55d |  | 6,171,552,458 | 1405/4/10 | 1405/4/23 |
| 363 | 5.5.18.1 | اجرای فونداسیون سیستم روشنایی | 8d | 2026-07-01 | 2026-07-08 | 142, 306, 341, 239, 156 | 2026-07-01 | 2026-07-08 | 8d | 55d | 0d | 3,042,519,003 | 1405/4/10 | 1405/4/17 |
| 364 | 5.5.18.2 | کابل کشی سیستم روشنایی | 5d | 2026-07-01 | 2026-07-05 | 123, 341 | 2026-07-01 | 2026-07-05 | 5d | 64d | 9d | 2,190,323,418.5 | 1405/4/10 | 1405/4/14 |
| 365 | 5.5.18.3 | نصب پایه ها و چراغ ها | 6d | 2026-07-09 | 2026-07-14 | 363 | 2026-07-09 | 2026-07-14 | 6d | 55d | 0d | 938,710,036.5 | 1405/4/18 | 1405/4/23 |
| 366 | 5.5.19 | **CCTV نصب سیستم** | 9d | 2026-07-01 | 2026-07-09 |  | 2026-07-01 | 2026-07-09 | 9d | 59d |  | 15,085,969,586 | 1405/4/10 | 1405/4/18 |
| 367 | 5.5.19.1 | اجرای فونداسیون دوربین | 5d | 2026-07-01 | 2026-07-05 | 177, 178, 291, 341, 235 | 2026-07-01 | 2026-07-05 | 5d | 59d | 0d | 3,017,193,917.2 | 1405/4/10 | 1405/4/14 |
| 368 | 5.5.19.2 | کابل کشی دوربین ها | 5d | 2026-07-01 | 2026-07-05 | 123, 341 | 2026-07-01 | 2026-07-05 | 5d | 63d | 4d | 7,542,984,793 | 1405/4/10 | 1405/4/14 |
| 369 | 5.5.19.3 | نصب پایه ها و دوربین ها | 4d | 2026-07-06 | 2026-07-09 | 367 | 2026-07-06 | 2026-07-09 | 4d | 59d | 0d | 4,525,790,875.8 | 1405/4/15 | 1405/4/18 |
| 370 | 6 | **مستندات حوزه کیفیت و مدیریت پروژه** | 200d | 2026-02-19 | 2026-09-11 |  |  |  |  | 1d |  | 9,255,412,954.68 | 1404/11/30 | 1405/6/20 |
| 371 | 6.1 | **مستندات حوزه کیفیت مطابق MDL ارایه شده** | 182d | 2026-03-05 | 2026-09-07 |  | 2026-03-25 | 2026-09-08 | 168d | 0d |  | 6,273,700,789.32 | 1404/12/14 | 1405/6/16 |
| 372 | 6.1.1 | Solar Panel Installation Manual & Operation & Maintenance | 1d | 2026-04-04 | 2026-04-04 | 273 | 2026-04-04 | 2026-04-04 | 1d | 155d |  | 621,190,034.45 | 1405/1/15 | 1405/1/15 |
| 373 | 6.1.2 | Inverter Installation Manual & Operation & Maintenance | 1d | 2026-05-17 | 2026-05-17 | 279 | 2026-05-17 | 2026-05-17 | 1d | 112d |  | 621,190,034.45 | 1405/2/27 | 1405/2/27 |
| 374 | 6.1.3 | MV Station Installation Manual & Operation & Maintenance | 1d | 2026-05-17 | 2026-05-17 | 285 | 2026-05-17 | 2026-05-17 | 1d | 112d |  | 621,190,034.45 | 1405/2/27 | 1405/2/27 |
| 375 | 6.1.4 | UPS Installation Manual & Operation & Maintenance | 1d | 2026-04-18 | 2026-04-18 | 242 | 2026-04-18 | 2026-04-18 | 1d | 141d |  | 49,695,202.8 | 1405/1/29 | 1405/1/29 |
| 376 | 6.1.5 | AUX Transformer Installation Manual & Operation & Maintenance | 1d | 2026-04-06 | 2026-04-06 | 198 | 2026-04-06 | 2026-04-06 | 1d | 153d |  | 63,711,798.6 | 1405/1/17 | 1405/1/17 |
| 377 | 6.1.6 | Diesel Generator Installation Manual & Operation & Maintenance | 1d | 2026-04-06 | 2026-04-06 | 198 | 2026-04-06 | 2026-04-06 | 1d | 153d |  | 63,711,798.6 | 1405/1/17 | 1405/1/17 |
| 378 | 6.1.7 | Weather Station Installation Manual & Operation & Maintenance | 1d | 2026-03-05 | 2026-03-05 | 255 | 2026-04-08 | 2026-04-08 | 1d | 180d |  |  | 1404/12/14 | 1404/12/14 |
| 379 | 6.1.8 | Solar Structure Installation Manual & Operation & Maintenance | 1d | 2026-03-25 | 2026-03-25 | 267 | 2026-03-25 | 2026-03-25 | 1d | 165d |  |  | 1405/1/5 | 1405/1/5 |
| 380 | 6.1.9 | SCADA and Monitoring System Installation Manual & Operation & Maintenance | 1d | 2026-07-05 | 2026-07-05 | 408 | 2026-07-05 | 2026-07-05 | 1d | 63d |  | 31,855,899 | 1405/4/14 | 1405/4/14 |
| 381 | 6.1.10 | Project O&M General Instructions | 1d | 2026-05-17 | 2026-05-17 | 242, 267, 273, 279, 285 | 2026-05-17 | 2026-05-17 | 1d | 112d |  | 621,190,034.45 | 1405/2/27 | 1405/2/27 |
| 382 | 6.1.11 | Test Report of Solar Structure | 2d | 2026-03-25 | 2026-03-26 | 267 | 2026-03-25 | 2026-03-26 | 2d | 164d |  |  | 1405/1/5 | 1405/1/6 |
| 383 | 6.1.12 | Test Reports for PV Modules | 2d | 2026-04-04 | 2026-04-05 | 273 | 2026-04-04 | 2026-04-05 | 2d | 154d |  | 621,190,034.45 | 1405/1/15 | 1405/1/16 |
| 384 | 6.1.13 | Test Reports for Inverter | 2d | 2026-05-17 | 2026-05-18 | 279 | 2026-05-17 | 2026-05-18 | 2d | 111d |  | 621,190,034.45 | 1405/2/27 | 1405/2/28 |
| 385 | 6.1.14 | Test Reports for MV Sation | 2d | 2026-05-17 | 2026-05-18 | 285 | 2026-05-17 | 2026-05-18 | 2d | 111d |  | 621,190,034.45 | 1405/2/27 | 1405/2/28 |
| 386 | 6.1.15 | Test Reports for AC and DC Cables | 2d | 2026-08-29 | 2026-08-30 | 410 | 2026-08-29 | 2026-08-30 | 2d | 7d |  | 372,714,020.5 | 1405/6/7 | 1405/6/8 |
| 387 | 6.1.16 | Test Reports for Diesel Generators | 1d | 2026-09-06 | 2026-09-06 | 420 | 2026-09-07 | 2026-09-07 | 1d | 0d |  | 63,711,798.6 | 1405/6/15 | 1405/6/15 |
| 388 | 6.1.17 | Test Reports for AUX Transformer | 1d | 2026-09-06 | 2026-09-06 | 420 | 2026-09-07 | 2026-09-07 | 1d | 0d |  | 63,711,798.6 | 1405/6/15 | 1405/6/15 |
| 389 | 6.1.18 | Test Reports for Earthing and Ligthtning | 2d | 2026-07-21 | 2026-07-22 | 409, 419 | 2026-07-21 | 2026-07-22 | 2d | 46d |  | 602,713,613 | 1405/4/30 | 1405/4/31 |
| 390 | 6.1.19 | Test Reports for MV Switchgear (CT, PT, Relay, …) | 2d | 2026-08-14 | 2026-08-15 | 407 | 2026-08-14 | 2026-08-15 | 2d | 22d |  | 191,135,395 | 1405/5/23 | 1405/5/24 |
| 391 | 6.1.20 | Test Reports for UPS and Battery | 2d | 2026-08-23 | 2026-08-24 | 414 | 2026-08-24 | 2026-08-25 | 2d | 13d |  | 49,695,202.8 | 1405/6/1 | 1405/6/2 |
| 392 | 6.1.21 | کدگذاری و تحویل مستندات پروژه | 1d | 2026-09-07 | 2026-09-07 | 372, 373, 374, 375, 376, 377, 378, 379, 380, 381, 382, 383, 384, 385, 386, 387, 388, 389, 390, 391 | 2026-09-08 | 2026-09-08 | 1d | 0d |  | 372,714,020.67 | 1405/6/16 | 1405/6/16 |

| ID | WBS | Task | Duration | Start | Finish | Predecessors | Baseline start | Baseline finish | Baseline duration | Total slack | Free slack | Cost | start shamsi | finish shamsi |
| --- | --- | --- | --- | --- | --- | --- | --- | --- | --- | --- | --- | --- | --- | --- |
| 393 | 6.2 | **گزارشات مدیریت پروژه** | 200d | 2026-02-19 | 2026-09-11 |  |  |  |  | 1d |  | 2,981,712,165.36 | 1404/11/30 | 1405/6/20 |
| 394 | 6.2.1 | Monthly Report 410-M-001 | 5d | 2026-02-19 | 2026-02-23 | 20, 21, 6FS+23d |  |  |  | 1d | 0d | 372,714,020.67 | 1404/11/30 | 1404/12/4 |
| 395 | 6.2.2 | Monthly Report 410-M-002 | 5d | 2026-03-19 | 2026-03-28 | 394FS+23d |  |  |  | 1d | 0d | 372,714,020.67 | 1404/12/28 | 1405/1/8 |
| 396 | 6.2.3 | Monthly Report 410-M-003 | 5d | 2026-04-21 | 2026-04-25 | 395FS+23d |  |  |  | 1d | 0d | 372,714,020.67 | 1405/2/1 | 1405/2/5 |
| 397 | 6.2.4 | Monthly Report 410-M-004 | 5d | 2026-05-22 | 2026-05-26 | 396FS+26d |  |  |  | 1d | 0d | 372,714,020.67 | 1405/3/1 | 1405/3/5 |
| 398 | 6.2.5 | Monthly Report 410-M-005 | 5d | 2026-06-22 | 2026-06-26 | 397FS+26d |  |  |  | 1d | 0d | 372,714,020.67 | 1405/4/1 | 1405/4/5 |
| 399 | 6.2.6 | Monthly Report 410-M-006 | 5d | 2026-07-23 | 2026-07-27 | 398FS+26d |  |  |  | 1d | 0d | 372,714,020.67 | 1405/5/1 | 1405/5/5 |
| 400 | 6.2.7 | Monthly Report 410-M-007 | 5d | 2026-08-23 | 2026-08-27 | 399FS+26d |  |  |  | 1d | 0d | 372,714,020.67 | 1405/6/1 | 1405/6/5 |
| 401 | 6.2.8 | Monthly Report 410-M-008 | 5d | 2026-09-07 | 2026-09-11 | 400FS+10d |  |  |  | 1d |  | 372,714,020.67 | 1405/6/16 | 1405/6/20 |
| 402 | 7 | **تست و تحویل** | 71d | 2026-07-04 | 2026-09-12 |  | 2026-03-25 | 2026-09-12 | 172d | 0d |  | 15,592,188,423.32 | 1405/4/13 | 1405/6/21 |
| 403 | 7.1 | **تست و راه اندازی نیروگاه** | 67d | 2026-07-04 | 2026-09-08 |  | 2026-03-25 | 2026-09-12 | 172d | 0d |  | 10,871,144,161.5 | 1405/4/13 | 1405/6/17 |
| 404 | 7.1.1 | تست کلیه کابل های فشار ضعیف نیروگاهac | 2d | 2026-08-14 | 2026-08-15 | 346 | 2026-08-14 | 2026-08-15 | 2d | 24d |  | 2,847,917,389 | 1405/5/23 | 1405/5/24 |
| 405 | 7.1.2 | تست کلیه کابل های فشار متوسط نیروگاهac | 2d | 2026-07-12 | 2026-07-13 | 347 | 2026-07-12 | 2026-07-13 | 2d | 57d |  | 955,676,976 | 1405/4/21 | 1405/4/22 |
| 406 | 7.1.3 | تست کابل dc | 4d | 2026-09-05 | 2026-09-08 | 348 | 2026-09-05 | 2026-09-08 | 4d | 0d |  | 1,191,410,630 | 1405/6/14 | 1405/6/17 |
| 407 | 7.1.4 | تست تابلوهای فشار متوسط و کلیه متعلقات | 1d | 2026-08-13 | 2026-08-13 | 344 | 2026-08-13 | 2026-08-13 | 1d | 22d | 0d | 509,694,387 | 1405/5/22 | 1405/5/22 |
| 408 | 7.1.5 | تست کابل شبکه مورد نیازسیستم انتقال دیتا و اسکادا | 1d | 2026-07-04 | 2026-07-04 | 349 | 2026-07-04 | 2026-07-04 | 1d | 63d | 0d | 31,855,899 | 1405/4/13 | 1405/4/13 |
| 409 | 7.1.6 | تست سیستم زمین نیروگاه | 2d | 2026-07-16 | 2026-07-17 | 343 | 2026-07-16 | 2026-07-17 | 2d | 46d | 0d | 1,205,427,226 | 1405/4/25 | 1405/4/26 |
| 410 | 7.1.7 | تست کلیه متعلقات مربوط به کابل کشی و سیم کشی | 2d | 2026-08-27 | 2026-08-28 | 358, 359, 360, 361 | 2026-08-27 | 2026-08-28 | 2d | 7d | 0d | 372,714,020.5 | 1405/6/5 | 1405/6/6 |
| 411 | 7.1.8 | تست تابلوهای فشار ضعیف و کلیه متعلقات | 2d | 2026-08-10 | 2026-08-11 | 345 | 2026-08-10 | 2026-08-11 | 2d | 28d |  | 191,135,395 | 1405/5/19 | 1405/5/20 |
| 412 | 7.1.9 | تست کلیه ملزومات و تجهیزات مربوط به ایجاد شبکه انتقال دیتا و بستر مخابراتی با پست بالادست | 1d | 2026-07-12 | 2026-07-12 | 352 | 2026-07-12 | 2026-07-12 | 1d | 58d | 0d | 496,952,028 | 1405/4/21 | 1405/4/21 |
| 413 | 7.1.10 | تست کلیه ملزومات و تجهیزات مربوط به ایجاد شبکه انتقال دیتا و ارسال دیتا | 1d | 2026-09-06 | 2026-09-06 | 356 | 2026-09-07 | 2026-09-07 | 1d | 2d |  | 197,506,575 | 1405/6/15 | 1405/6/15 |
| 414 | 7.1.11 | تست یو پی اس | 1d | 2026-08-22 | 2026-08-22 | 354 | 2026-08-23 | 2026-08-23 | 1d | 13d | 0d | 66,260,270.4 | 1405/5/31 | 1405/5/31 |
| 415 | 7.1.12 | تست کلیه تجهیزات مربوط به دوربین | 2d | 2026-07-10 | 2026-07-11 | 368, 369 | 2026-07-10 | 2026-07-11 | 2d | 59d |  | 1,274,235,968 | 1405/4/19 | 1405/4/20 |
| 416 | 7.1.13 | تست سیستم روشنایی | 1d | 2026-07-15 | 2026-07-15 | 364, 365 | 2026-07-15 | 2026-07-15 | 1d | 55d |  | 159,279,496 | 1405/4/24 | 1405/4/24 |
| 417 | 7.1.14 | تست سیستم اعلام حریق | 1d | 2026-08-11 | 2026-08-11 | 316, 324, 333 | 2026-08-12 | 2026-08-12 | 1d | 28d |  | 25,484,719 | 1405/5/20 | 1405/5/20 |
| 418 | 7.1.15 | تست سیستم اطفا حریق | 1d | 2026-08-21 | 2026-08-21 | 317, 325, 334 | 2026-08-22 | 2026-08-22 | 1d | 18d |  | 76,454,158 | 1405/5/30 | 1405/5/30 |
| 419 | 7.1.16 | تست سیستم حفاظت صاعقه | 1d | 2026-07-20 | 2026-07-20 | 355 | 2026-07-20 | 2026-07-20 | 1d | 46d | 0d | 1,205,427,226 | 1405/4/29 | 1405/4/29 |
| 420 | 7.1.17 | تست ترانسفورماتور کمکی و دیزل | 1d | 2026-09-05 | 2026-09-05 | 353 | 2026-09-06 | 2026-09-06 | 1d | 0d |  | 63,711,798.6 | 1405/6/14 | 1405/6/14 |

| ID | WBS | Task | Type | Duration | Start | Finish | Predecessors | Baseline start | Baseline finish | Baseline duration | Total slack | Cost | start shamsi | finish shamsi |
| --- | --- | --- | --- | --- | --- | --- | --- | --- | --- | --- | --- | --- | --- | --- |
| 421 | 7.2 | **ارایه نقشه های ازبیلت** |  | 22d | 2026-08-22 | 2026-09-12 |  | 2026-08-22 | 2026-09-12 | 22d | 0d | 3,727,140,206.7 | 1405/5/31 | 1405/6/21 |
| 422 | 7.2.1 | ارایه نقشه های ازبیلت الکتریکال |  | 4d | 2026-09-09 | 2026-09-12 | 404, 405, 406, 407, 408, 409, 410, 411, 412, 413, 414, 415, 416, 417, 418, 419, 420, 17 | 2026-09-09 | 2026-09-12 | 4d | 0d | 1,242,380,068.9 | 1405/6/18 | 1405/6/21 |
| 423 | 7.2.2 | ارایه نقشه های ازبیلت مکانیکال |  | 7d | 2026-08-22 | 2026-08-28 | 339, 12 | 2026-08-22 | 2026-08-28 | 7d | 15d | 1,242,380,068.9 | 1405/5/31 | 1405/6/6 |
| 424 | 7.2.3 | ارایه نقشه های ازبیلت civil |  | 7d | 2026-09-04 | 2026-09-10 | 315, 323, 332, 309 | 2026-09-05 | 2026-09-11 | 7d | 2d | 1,242,380,068.9 | 1405/6/13 | 1405/6/19 |
| 425 | 7.3 | **راه اندازی، اتصال به شبکه و پلمپ کنتور** |  | 1d | 2026-09-09 | 2026-09-09 |  | 2026-09-09 | 2026-09-09 | 1d | 0d | 372,714,020.67 | 1405/6/18 | 1405/6/18 |
| 426 | 7.3.1 | راه اندازی، اتصال به شبکه و پلمپ کنتور |  | 1d | 2026-09-09 | 2026-09-09 | 404, 405, 406, 407, 408, 409, 410, 411, 412, 413, 414, 415, 416, 417, 418, 419, 420, 291 |  |  |  | 0d |  | 1405/6/18 | 1405/6/18 |
| 427 | 7.4 | **آموزش** |  | 6d | 2026-09-07 | 2026-09-12 |  | 2026-09-07 | 2026-09-12 | 6d | 0d | 621,190,034.45 | 1405/6/16 | 1405/6/21 |
| 428 | 7.4.1 | آموزش |  | 6d | 2026-09-07 | 2026-09-12 | 160, 426FS-3d |  |  |  | 0d |  | 1405/6/16 | 1405/6/21 |
| 429 | 7.5 | **برچیدن کارگاه** |  | 5d | 2026-09-08 | 2026-09-12 |  | 2026-09-09 | 2026-09-12 | 4d | 0d |  | 1405/6/17 | 1405/6/21 |
| 430 | 7.5.1 | برچیدن کارگاه |  | 5d | 2026-09-08 | 2026-09-12 | 426FS-3d, 392 |  |  |  | 0d |  | 1405/6/17 | 1405/6/21 |
| 431 | 8 | پایان | milestone | 0d | 2026-09-12 | 2026-09-12 | 422, 423, 424, 301, 145, 22, 426, 428, 430, 257, 401 | 2026-09-12 | 2026-09-12 | 0d | 0d |  | 1405/6/21 | 1405/6/21 |
